# 3GPP_Work Plan

Schedule from MS Project, 2000-01-03 to 2005-12-15, A marks actual dates.

## Calendars

- Standard: Mon-Fri 08:00-12:00, 13:00-17:00; Sat-Sun off.

## Resources

| Resource |
| --- |
| NP |
| N1 |
| N2 |
| N3 |
| N4 |
| N5 |
| TP |
| T1 |
| T2 |
| T3 |
| RP |
| R1 |
| R2 |
| R3 |
| R4 |
| SP |
| S1 |
| S2 |
| S3 |
| S4 |
| S5 |
| PCG |
| GP |
| No |
| CN4 |
| ? |
| WG G2 |
| G2 |
| G1 |
| G4 |
| G3 |
| All |
| Generic |
| MLST |
| G5 |
| S3, G2 |
| WG T2 |
| GP,G1 |
| G4,G5 |
| OMA |
| GP-G2 |
| Yes |

## Schedule

| ID | WBS | Task | Duration | Start | Finish | Complete | Remaining | Baseline start | Baseline finish | Baseline duration | Total slack | Constraint | Resources | Work | Actual work | Text6 | Text9 | Text1 | Text4 | Text5 | Text7 | Text8 | Text11 | Text3 | Text10 | Text2 | Text12 |
| --- | --- | --- | --- | --- | --- | --- | --- | --- | --- | --- | --- | --- | --- | --- | --- | --- | --- | --- | --- | --- | --- | --- | --- | --- | --- | --- | --- |
| 1 | 1 | VERSION 2004 September 8th | 1d | 2000-01-03 | 2000-01-03 |  |  | 2000-01-03 | 2000-01-03 | 1d | 1800d |  |  |  |  | Rel | 2044 |  |  |  |  |  |  |  |  |  |  |
| 2 | 2 | "CTRL + a" to display all the 3GPP fields | 1d | 2000-01-03 | 2000-01-03 |  |  | 2000-01-03 | 2000-01-03 | 1d | 1800d |  |  |  |  |  | 1462 |  |  |  |  |  |  |  |  |  |  |
| 3 | 3 | Content of Rel-6 and after. Not frozen. | 1d | 2000-01-03 | 2000-01-03 |  |  | 2000-01-03 | 2000-01-03 | 1d | 1800d |  |  |  |  | Rel | 2058 |  |  |  |  |  |  |  |  |  |  |
| 5 | 4 | Evolutions of the transport in the UTRAN | 218d | 2003-03-03 | 2003-12-31 |  |  | 2003-03-03 | 2003-12-31 | 218d | 758d | start no earlier than 2003-03-03 | RP | 1744h |  | NA | Feat | ETRAN | Francois Courau, Alcatel | francois.courau@alcatel.fr | TSG | Cesar | Generic |  |  |  |  |
| 6 | 8 | **Improvements of Radio Interface** | 1196d | 2000-08-14 A | 2005-03-15 | 78% | 269.05d | 2000-08-14 | 2004-09-15 | 1068d | 198d |  | RP | 41168h | 30970.8h | Rel-6 |  | RInImp |  |  | TSG | Cesar |  |  |  |  |  |
| 7 | 5.1 | Improvement of inter-frequency and inter-system measurement | 968d | 2001-01-01 A | 2004-09-15 | 50% | 484d | 2001-01-01 | 2004-09-15 | 968d | 573d | finish no earlier than 2004-09-15 | R1 | 7744h | 3872h | Rel-6 | BB | RInImp-IfIsM | Antti Toskala, Nokia | antti.toskala@nokia.com | TSG | MCC RAN | Active | TS25.212, 25.215, 25.331, 25.423, 25.433 | 1216 |  |  |
| 8 | 5.2 | Improving Receiver Performance Requirements for the FDD UE | 401d | 2002-03-08 A | 2003-09-19 A | 100% |  | 2002-03-08 | 2003-09-19 | 401d |  | start no earlier than 2002-03-08 | R4 | 3208h | 3208h | Rel-6 | BB | RInImp-UERecPerf | Shimon Moshavi, Intel | shimon.moshavi@INTEL.COM | TSG |  | Active | TS25.101 | 1216 |  |  |
| 9 | 8.2 | **Base station classification** | 603d | 2000-08-14 A | 2002-12-04 A | 100% |  | 2000-08-14 | 2002-12-04 | 603d |  |  | R4 | 9648h | 9648h | Rel-6 |  | RInImp-BSClass |  |  | TSG |  |  |  |  |  |  |
| 10 | 8.2.1 | FDD Base station classification | 603d | 2000-08-14 A | 2002-12-04 A | 100% |  | 2000-08-14 | 2002-12-04 | 603d |  | finish no earlier than 2002-12-04 | R4 | 4824h | 4824h | Rel-6 | 1476 | RInImp-BSClass-FDD | A. Toskala, Nokia |  | TSG |  |  | TS25.104, TS25.141 |  | BaAs |  |
| 11 | 5.4 | UMTS-850 | 266d | 2002-12-06 A | 2003-12-12 A | 100% |  | 2002-12-06 | 2003-12-12 | 266d |  | finish no earlier than 2003-12-15 | R4 | 2128h | 2128h | Rel-6 | BB | RInImp-UMTS850 | Don Zelmer, Cingular | don.zelmer@cingular.com | TSG | MCC_RAN | Active | TS25.101, 25.104, 25.133, 25.141, 25.307, 25.331, TR25.942 | 1216 |  |  |
| 12 | 5.5 | DS-CDMA introduction in the 800 MHz band | 196d | 2003-03-14 A | 2003-12-12 A | 100% |  | 2003-03-14 | 2003-12-12 | 196d |  | finish no earlier than 2003-12-15 | R4 | 1568h | 1568h | Rel-6 | BB | RInImp-UMTS800 | Takehiro Nakamura, NTT DoCoMo | takehiro@wsp.yrp.nttdocomo.co.jp | TSG | MCC_RAN | Active | TS25.101, 25.104, 25.133, 25.141, 25.307, 25.331 | 1216 |  |  |
| 13 | 5.6 | UMTS 1.7/2.1 GHz | 261d | 2003-03-14 A | 2004-03-12 A | 100% |  | 2003-03-14 | 2004-03-12 | 261d |  | finish no earlier than 2004-03-15 | R4 | 2088h | 2088h | Rel-6 | BB | RInImp-UMTS1721 | Jussi Numminen, Nokia | jussi.numminen@NOKIA.COM | TSG | MCC RAN | Active | TS25.101, 25.104, 25.133, 25.141, 25.307, 25.331 | 1216 |  |  |
| 14 | 5.7 | **Improved Receiver Performance Requirements for HSDPA** | 326d | 2003-12-15 A | 2005-03-15 | 40% | 195.6d | 2003-12-15 | 2004-09-14 | 197d | 198d |  | R4 | 5216h | 1043.2h | Rel-6 |  | RInImp-HSPerf | Jussi Numminen, Nokia | jussi.numminen@NOKIA.COM | TSG | MCC RAN |  |  |  |  |  |
| 15 | 5.7.1 | Performance Requirements of Receive Diversity for HSDPA | 326d | 2003-12-15 A | 2005-03-15 | 40% | 195.6d | 2003-12-15 | 2004-09-14 | 197d | 445d | finish no earlier than 2005-03-15 | R4 | 2608h | 1043.2h | Rel-6 |  | RInImp-HSPerf-RxDiv | Takehiro Nakamura (NTT DoCoMo) | takehiro@wsp.yrp.nttdocomo.co.jp | TSG | MCC RAN |  | TS25.101 |  |  |  |
| 16 | 6 | **RAN Feasibility Studies** | 1197d? | 2000-08-14 A | 2005-03-15 | 81% | 223.45d? | 2000-08-14 | 2005-03-15 | 1197d | 197d |  | RP | 43064h | 29683.2h | Rel-6 |  |  |  |  |  | Cesar |  |  |  |  |  |
| 17 | 6.1 | FS of the improved access to UE measurement data for CRNC to support TDD RRM | 270d? | 2002-12-06 A | 2003-12-18 A | 100% |  | 2002-12-06 | 2003-12-18 | 270d? |  | finish no earlier than 2003-09-19 | R3 | 2160h | 2160h | Rel-6 |  | RANimp-RRMopt-FSUEMsD | Jim Miller, Interdigital | jim.miller@interdigital.com | TSG |  |  |  |  |  |  |
| 18 | 6.2 | FS on Radio link performance enhancements | 1067d | 2000-08-14 A | 2004-09-15 | 95% | 53.35d | 2000-08-14 | 2004-06-15 | 1002d | 574d | finish no earlier than 2004-09-15 | R1 | 8536h | 8109.2h | Rel-6 | SI | RInImp-Rlperf | Antti Toskala, Nokia Networks | antti.toskala@nokia.com | TSG | MCC_RAN | Active | TR25.899 | 1216 |  |  |
| 19 | 6.3 | FS on Improvement of inter-frequency and inter-system measurements for 1.28 Mcps TDD | 461d | 2001-12-14 A | 2003-09-19 A | 100% |  | 2001-12-14 | 2003-09-19 | 461d |  | start no earlier than 2001-12-14 | R1 | 3688h | 3688h | Rel-6 | SI | RInImp-IfIsMLCR | Li Xiao Qiang, SAMSUNG | xqli@samsung.co.kr | TSG |  | Active | TR25.888 | 1216 |  | 10 |
| 20 | 6.4 | FS for the analysis of OFDM for UTRAN enhancement | 526d | 2002-06-10 A | 2004-06-14 A | 100% |  | 2002-06-10 | 2004-06-14 | 526d |  | start no earlier than 2002-06-10 | R1 | 4208h | 4208h | Rel-6 | SI | RInImp-FSOFDM | Sarah Boumendil, Nortel | boumendi@nortelnetworks.com | TSG | MCC_RAN | Active | TR25.892 | 1216 |  | 11 |
| 21 | 6.5 | FS on Uplink Enhancements for Dedicated Transport Channels | 396d | 2002-09-06 A | 2004-03-12 A | 100% |  | 2002-09-06 | 2004-03-12 | 396d |  | finish no earlier than 2004-03-12 | R1 | 3168h | 3168h | Rel-6 | SI | RInImp-FSUpDTrCh | Karri Ranta-aho, Nokia | Karri.Ranta-aho@nokia.com | TSG | MCC_RAN | Active | TR25.896 | 1216 |  | 12 |
| 22 | 6.6 | FS on Analysis on Higher Chip Rates for UTRA TDD evolutions | 528d | 2002-09-06 A | 2004-09-15 | 90% | 52.8d | 2002-09-06 | 2004-06-14 | 462d | 574d | finish no earlier than 2004-09-15 | R1 | 4224h | 3801.6h | Rel-6 | SI | RInImp-FSVHCRTDD | Tim Wilkinson, IPWireless | mbeale@ipwireless.com | TSG | MCC_RAN | Active | TR25.895 | 1216 |  | 13 |
| 23 | 6.7 | FS on Low Output Powers for general purpose FDD BSs | 128d | 2003-06-13 A | 2004-03-12 A | 100% |  | 2003-06-13 | 2004-03-12 | 128d |  | finish no earlier than 2004-03-12 | R3 | 1024h | 1024h | Rel-6 | SI | RInImp-FSLoPw | Ana Burgos, Telefonica | burgos_a@tsm.es | TSG | MCC_RAN | Active | TR25.807 | 1216 |  | 14 |
| 24 | 6.8 | FS on Uplink enhancements for UTRA TDD | 398d | 2003-06-06 A | 2004-12-15 | 20% | 318.4d | 2003-06-06 | 2004-09-14 | 333d | 509d | finish no earlier than 2004-12-15 | R1 | 3184h | 636.8h | Rel-6 | SI | RInImp-FSUpEnhTDD | Marian Rudolf, Interdigital | Marian.Rudolf@InterDigital.com | TSG | MCC_RAN | Active | TR25.804 | 1216 |  | 15 |
| 25 | 8.8 | FS on UE antenna efficiency test methods performance requirements (2) | 131d | 2002-03-08 A | 2002-09-06 A | 100% |  | 2002-03-08 | 2002-09-06 | 131d |  | finish no earlier than 2002-09-06 | R4 | 1048h | 1048h | Rel-6 |  | RInImp-UEAnTM2 | Alf Ahlström, Allgon |  | TSG |  |  |  |  |  |  |
| 26 | 9.4 | FS on the evolution of the UTRAN architecture | 657d | 2002-09-09 A | 2005-03-15 | 35% | 427.05d | 2002-09-09 | 2005-03-15 | 657d | 444d | finish no earlier than 2005-03-15 | R3 | 5256h | 1839.6h | Rel-6 |  | RANimp-FSEvo | Woonhee Hwang, Nokia | Antti.Toskala@nokia.com | TSG | MCC_RAN |  |  |  |  |  |

Notes:
- 5: Generic feature
- 6: This is a generic feature without particular end date
- 25: The RInImp-UEAnTM FS was re-opened at TSG RAN#15 upon request from WG4
- 26: Work stopped until completion of MBMS in RAN3

| ID | WBS | Task | Duration | Start | Finish | Complete | Remaining | Baseline start | Baseline finish | Baseline duration | Total slack | Constraint | Resources | Work | Actual work | Text1 | Text4 | Text5 | Text6 | Text7 | Text8 | Text9 | Text10 | Text11 | Text12 | Text2 |
| --- | --- | --- | --- | --- | --- | --- | --- | --- | --- | --- | --- | --- | --- | --- | --- | --- | --- | --- | --- | --- | --- | --- | --- | --- | --- | --- |
| 27 | 8.5 | **Multiple Input Multiple Output antennas (MIMO)** | 719d? | 2003-03-14 A | 2005-12-15 | 10% | 647.04d? | 2003-03-14 | 2005-03-15 | 523d? | 1d |  | R1 | 23552h | 3880.8h | MIMO | Howard Huang, Lucent | hchuang@lucent.com | Rel-6 | TSG | Cesar | 2468 |  |  |  |  |
| 28 | 7.1 | MIMO - Physical layer | 393d? | 2003-09-12 A | 2005-03-15 | 50% | 196.5d? | 2003-09-12 | 2005-03-15 | 393d? | 444d | finish no earlier than 2004-09-14 | R1 | 3144h | 1572h | MIMO-Phys | Howard Huang, Lucent | hchuang@lucent.com | Rel-6 | TSG | MCC RAN |  |  |  |  |  |
| 29 | 7.2 | MIMO - Layer 2,3 aspects | 589d? | 2003-09-12 | 2005-12-15 |  |  | 2003-09-12 | 2004-12-15 | 329d? | 248d | finish no earlier than 2005-12-15 | R2 | 4712h |  | MIMO-L23 | Howard Huang, Lucent | hchuang@lucent.com | Rel-6 | TSG | MCC RAN |  |  |  |  |  |
| 30 | 7.3 | MIMO - Iub/Iur Protocol Aspects | 719d? | 2003-03-14 | 2005-12-15 |  |  | 2003-03-14 | 2004-12-15 | 459d? | 248d | finish no earlier than 2005-12-15 | R3 | 5752h |  | MIMO-IurIub | Howard Huang, Lucent | hchuang@lucent.com | Rel-6 | TSG | MCC RAN |  |  |  |  |  |
| 31 | 7.4 | MIMO - RF Radio Transmission/Reception, System Performance Requirements and Conformance Testing | 524d? | 2003-12-12 A | 2005-12-15 | 5% | 497.8d? | 2003-12-12 | 2005-03-15 | 328d? | 248d | finish no earlier than 2005-12-15 | R4 | 4192h | 209.6h | MIMO-RF | Man Hung Ng, Lucent | ngm@lucent.com | Rel-6 | TSG | MCC RAN |  |  |  |  |  |
| 32 | 8 | **FDD Enhanced Uplink** | 327d | 2004-03-15 A | 2005-06-15 | 6% | 308.46d | 2004-03-15 | 2005-06-15 | 327d | 132d |  | RP | 11024h | 476.8h | EDCH | Joakim Bergström (Ericsson) |  | Rel-6 | TSG | Cesar | Feat | 20003 | Active |  |  |
| 33 | 8.1 | FDD Enhanced Uplink - Stage 2 | 133d | 2004-03-15 A | 2004-09-15 | 30% | 93.1d | 2004-03-15 | 2004-03-15 | 1d | 573d | finish no earlier than 2004-09-15 | R2 | 1064h | 319.2h | EDCH-Stage2 |  |  | Rel-6 | TSG |  |  |  |  |  |  |
| 34 | 8.2 | FDD Enhanced Uplink - Physical Layer | 197d | 2004-03-15 A | 2004-12-15 | 5% | 187.15d | 2004-03-15 | 2004-12-15 | 197d | 509d | finish no earlier than 2004-12-15 | R1 | 1576h | 78.8h | EDCH-Phys | Karri Ranta-aho (Nokia) |  | Rel-6 | TSG | MCC RAN | BB | 20003 | Active | 26 |  |
| 35 | 8.3 | FDD Enhanced Uplink - Layer 2 and 3 Protocol Aspects | 197d | 2004-03-15 A | 2004-12-15 | 5% | 187.15d | 2004-03-15 | 2004-12-15 | 197d | 509d | finish no earlier than 2004-12-15 | R2 | 1576h | 78.8h | EDCH-L23 | Joakim Bergström (Ericsson) |  | Rel-6 | TSG | MCC RAN | BB | 20003 | Active | 27 |  |
| 36 | 8.4 | FDD Enhanced Uplink - UTRAN Iub/Iur Protocol Aspects | 197d | 2004-03-15 | 2004-12-15 |  |  | 2004-03-15 | 2004-12-15 | 197d | 509d | finish no earlier than 2004-12-15 | R3 | 1576h |  | EDCH-IurIub | Saso Stojanovski (Nortel) |  | Rel-6 | TSG | MCC RAN | BB | 20003 | Active | 28 |  |
| 37 | 8.5 | FDD Enhanced Uplink - RF Radio Transmission/ Reception, System Performance Requirements and Conformance Testing | 327d | 2004-03-15 | 2005-06-15 |  |  | 2004-03-15 | 2005-06-15 | 327d | 379d | finish no earlier than 2005-06-15 | R4 | 2616h |  | EDCH-RF | Thomas Unshelm (Ericsson) | thomas.unshelm@ERICSSON.COM | Rel-6 | TSG | MCC RAN | BB | 20003 | Active | 29 |  |
| 38 | 9 | **RAN improvements** | 592d? | 2002-09-09 A | 2004-12-15 | 55% | 268.08d? | 2002-09-09 | 2004-12-15 | 592d? | 262d |  | RP | 27832h | 12761.2h | RANimp |  |  | Rel-6 | TSG | Cesar |  |  |  |  |  |
| 39 | 9.2 | **RAB support enhancement** | 458d? | 2003-03-14 A | 2004-12-15 | 11% | 406.76d? | 2003-03-14 | 2004-12-15 | 458d? | 262d |  | R2 | 9384h | 852.8h | RANimp-RABSE | Juha Mikola, Nokia | juha.mikola@nokia.com | Rel-6 | TSG | MCC RAN | 624 |  |  |  | BaAS |
| 40 | 9.1.1 | Iu enhancements for IMS support in RAN | 320d? | 2003-03-14 A | 2004-06-04 | 25% | 240d? | 2003-03-14 | 2004-12-15 | 458d? | 647d | finish no earlier than 2004-06-04 | R3 | 2560h | 640h | RANimp-RABSE-IuEnhIMS | Phillipe Godin, Nortel | Philippe.Godin@nortelnetworks.com | Rel-6 | TSG | MCC RAN |  |  |  |  |  |
| 41 | 9.1.2 | Optimisation of downlink channelisation code utilisation | 198d | 2004-03-12 | 2004-12-15 |  |  | 2004-03-12 | 2004-12-15 | 198d | 509d | finish no earlier than 2004-12-15 | R1 | 1584h |  | RANimp-RABSE-CodeOptFDD | Sarah Boumendil (Nortel Networks) | boumendi@nortelnetworks.com | Rel-6 | TSG | MCC RAN | WT | 624 | Active |  |  |
| 42 | 9.1.3 | Optimisation of channelisation code utilisation for TDD | 197d | 2004-03-15 | 2004-12-15 |  |  | 2004-03-15 | 2004-12-15 | 197d | 509d | finish no earlier than 2004-12-15 | R1 | 1576h |  | RANimp-RABSE-CodeOptTDD | Nicholas Anderson (IPWireless) |  | Rel-6 | TSG | MCC RAN | WT | 624 | Active |  |  |
| 43 | 9.1 | Beamforming Enhancements | 66d | 2003-09-19 A | 2003-12-19 A | 100% |  | 2003-09-19 | 2003-12-19 | 66d |  | finish no earlier than 2004-03-12 | R1 | 528h | 528h | RANimp-BFE | Jussi Kähtävä, Nokia | jussi.kahtava@nokia.com | Rel-6 | TSG | MCC_RAN |  |  |  |  |  |
| 44 | 9.3 | **Rel6 RRM optimization for Iur and Iub** | 126d | 2003-09-19 A | 2004-03-12 A | 100% |  | 2003-09-19 | 2004-03-12 | 126d |  |  | R3 | 2016h | 2016h | RANimp-RRMopt | Gert-Jan van Lieshout, Ericsson | Gert-Jan.van.Lieshout@eln.ericsson.se | Rel-6 | TSG | MCC_RAN |  |  |  |  | BaAS |
| 45 | 9.3.1 | Improved access to User Equipment (UE) measurement data for Controlling Radio Network Controller (CRNC) to support Time Division Duplex (TDD) Radio Resource Management (RRM) | 126d | 2003-09-19 A | 2004-03-12 A | 100% |  | 2003-09-19 | 2004-03-12 | 126d |  | finish no earlier than 2004-03-15 | R3 | 1008h | 1008h | RANimp-RRMopt-UEMsD | Jim Miller, Interdigital | jim.miller@interdigital.com | Rel-6 | TSG | MCC RAN | WT | 23012 | Active | 22 |  |
| 46 | 9.4 | **Remote Control of Electrical Tilting Antennas** | 395d? | 2003-03-14 A | 2004-09-16 | 58% | 167.82d? | 2003-03-14 | 2004-09-16 | 395d? | 325d |  | R3 | 7472h | 3604.47h | RANimp-TiltAnt | Andreas Hauser, Vodafone | Andreas.Hauser@vodafone.com | Rel-6 | TSG | MCC_RAN |  |  |  |  |  |
| 47 | 9.4.1 | RAN aspects | 394d? | 2003-03-14 A | 2004-09-15 | 75% | 98.5d? | 2003-03-14 | 2004-09-15 | 394d? | 573d | finish no earlier than 2004-09-15 | R3 | 3152h | 2364h | RANimp-TiltAnt | Andreas Hauser, Vodafone | Andreas.Hauser@vodafone.com | Rel-6 | TSG | MCC_RAN |  |  |  |  |  |
| 48 | 9.4.2 | OAM&P impacts | 145d | 2004-02-27 A | 2004-09-16 | 10% | 130.5d | 2004-02-27 | 2004-09-16 | 145d | 572d | finish no earlier than 2004-09-16 | S5 | 1160h | 116h | RANimp-TiltAnt-OAM | John MUDGE, Vodafone | john.mudge@vodafone.co.uk | Rel-6 | WG | Adrian |  |  |  |  |  |
| 49 | 9.5 | Network Assisted Cell Change (NACC) from UTRAN to GERAN - network-side aspects | 462d? | 2002-09-09 A | 2004-06-15 A | 100% |  | 2002-09-09 | 2004-06-15 | 462d? |  | finish no earlier than 2004-06-15 | R3 | 3696h | 3696h | RANimp-NACC | Brendan McWilliams, Vodafone | Brendan.McWilliams@gb.vodafone.co.uk | Rel-6 | TSG | MCC_RAN |  |  |  |  |  |
| 50 | 12 | **Location Services enhancements 2** | 990d? | 2001-01-15 A | 2004-10-29 | 61% | 386.8d? | 2000-08-28 | 2004-10-29 | 1090d? | 294d |  | S2 | 79368h | 43794.1h | LCS2 |  |  | Rel-6 | TSG | Sang-Ui |  |  |  |  |  |
| 51 | 12.1 | **Improvement on Le interface** | 620d? | 2002-06-17 A | 2004-10-29 | 49% | 315.07d? | 2002-06-17 | 2004-10-29 | 620d? | 294d |  | S2 | 10344h | 5087.47h |  |  |  | Rel-6 | TSG |  |  |  |  |  |  |
| 52 | 10.1.1 | Stage 2 | 331d? | 2002-06-17 A | 2003-09-22 A | 100% |  | 2002-06-17 | 2003-09-22 | 331d? |  | start no earlier than 2002-06-17 | S2 | 2648h | 2648h |  |  |  | Rel-6 |  |  |  |  |  |  |  |
| 53 | 10.1.2 | Stage 3 - impacts MLP (Mobile Location Protocol) | 342d? | 2003-07-10 | 2004-10-29 |  |  | 2003-07-10 | 2004-10-29 | 342d? | 541d | finish no earlier than 2004-10-29 | OMA | 2736h |  |  |  | OMA-LIAISON@mail.openmobilealliance.org | Rel-6 |  |  |  |  |  |  |  |

Notes:
- 27: Text3: TR25.876,TR25.996
- 28: Text3: 25.211, 25.212, 25.213, 25.214, 25.215, 25.221, 25.222, 25.223, 25.224, 25.225
- 29: Text3: TR 25.876
- 33: Text3: TS 25.309
- 34: Text3: TS25.211, 25.212, 25.213, 25.214, 25.215
- 35: Text3: TS25.301, 25.302, 25.306, 25.321, 25.331
- 36: Text3: TS25.401, 25.420, 25.423, 25.430, 25.433
- 37: Text3: TS25.101, 25.104, 25.133, 25.141
- 38: Generic feature
- 39: This is a building block without particular end date / Text3: TR 25.862
- 40: Closed RAN#24 due to the lack of progress
- 43: Text3: TS24.215, 25.423, 25.425, 25.433, 25.435
- 45: Text3: TS25.423
- 47: Text3: TS25.460, 25.461, 25.462, 25.463
- 48: az: WID approved at SA5#37 (02/2004) / Text3: 32.804, 32.xyz
- 50: Text3: 23.271
- 53: Updated according to SP-040232

| ID | WBS | Task | Duration | Start | Finish | Complete | Remaining | Baseline start | Baseline finish | Baseline duration | Total slack | Constraint | Resources | Work | Actual work | Text6 | Text7 | Text5 | Text1 | Text8 | Text4 | Text9 | Text2 |
| --- | --- | --- | --- | --- | --- | --- | --- | --- | --- | --- | --- | --- | --- | --- | --- | --- | --- | --- | --- | --- | --- | --- | --- |
| 54 | 12.2 | **Enhanced support for anonymity and user privacy** | 605d? | 2002-07-08 A | 2004-10-29 | 43% | 346.58d? | 2002-07-08 | 2004-10-29 | 605d? | 294d |  | S2 | 9616h | 4072.03h | Rel-6 | TSG |  |  |  |  |  |  |
| 55 | 10.2.1 | Stage 2 | 255d? | 2002-07-08 A | 2003-06-27 A | 100% |  | 2002-07-08 | 2003-06-27 | 255d? |  | finish no earlier than 2003-06-27 | S2 | 2040h | 2040h | Rel-6 |  |  |  |  |  |  |  |
| 56 | 10.2.2 | Stage 3 - impacts MLP and RLP | 342d? | 2003-07-10 | 2004-10-29 |  |  | 2003-07-10 | 2004-10-29 | 342d? | 541d | finish no earlier than 2004-10-29 | OMA | 2736h |  | Rel-6 |  | OMA-LIAISON@mail.openmobilealliance.org |  |  |  |  |  |
| 57 | 12.3 | **Enhanced inter-GMLC interface** | 615d? | 2002-06-24 A | 2004-10-29 | 56% | 272.21d? | 2002-06-24 | 2004-10-29 | 615d? | 294d |  | S2 | 11960h | 6666.34h | Rel-6 | TSG |  |  |  |  |  |  |
| 58 | 10.3.1 | Stage 2 | 315d? | 2002-06-24 A | 2003-09-05 A | 100% |  | 2002-06-24 | 2003-09-05 | 315d? |  | finish no earlier than 2003-09-05 | S2 | 2520h | 2520h | Rel-6 |  |  |  |  |  |  |  |
| 59 | 10.3.2 | Stage 3 - definition of RLP and PCP | 565d? | 2002-09-02 A | 2004-10-29 | 31% | 389.5d? | 2002-09-02 | 2004-10-29 | 565d? | 541d | finish no earlier than 2004-10-29 | OMA | 4520h | 1404h | Rel-6 |  | OMA-LIAISON@mail.openmobilealliance.org |  |  |  |  |  |
| 60 | 12.4 | **Location Services support for IMS public identities** | 565d? | 2002-09-02 A | 2004-10-29 | 51% | 274.85d? | 2002-09-02 | 2004-10-29 | 565d? | 294d |  | S2 | 9960h | 4833.75h | Rel-6 | TSG |  |  |  |  |  |  |
| 61 | 10.4.1 | Stage 2 | 240d? | 2003-02-24 A | 2004-01-23 A | 100% |  | 2003-02-24 | 2004-01-23 | 240d? |  | finish no earlier than 2004-01-23 | S2 | 1920h | 1920h | Rel-6 |  |  |  |  |  |  |  |
| 62 | 10.4.2 | Stage 3 - impacts MLP, RLP and PCP | 565d? | 2002-09-02 A | 2004-10-29 | 31% | 391.6d? | 2002-09-02 | 2004-10-29 | 565d? | 541d | finish no earlier than 2004-10-29 | OMA | 4520h | 1387.2h | Rel-6 |  | OMA-LIAISON@mail.openmobilealliance.org |  |  |  |  |  |
| 63 | 12.5 | **New area event for location service triggering reports** | 630d? | 2002-06-03 A | 2004-10-29 | 59% | 259.45d? | 2002-06-03 | 2004-10-29 | 630d? | 294d |  | S2 | 11872h | 6250.43h | Rel-6 | TSG |  |  |  |  |  |  |
| 64 | 10.5.1 | Stage 2 | 280d? | 2002-06-03 A | 2003-06-27 A | 100% |  | 2002-06-03 | 2003-06-27 | 280d? |  | finish no earlier than 2003-06-27 | S2 | 2240h | 2240h | Rel-6 |  |  |  |  |  |  |  |
| 65 | 10.5.2 | Stage 3 for UE-CN signalling | 234d? | 2003-10-09 A | 2004-08-31 | 95% | 11.7d? | 2003-10-09 | 2004-08-31 | 234d? | 584d | start no earlier than 2003-10-09 | N4 | 1872h | 1778.4h | Rel-6 |  |  |  |  |  |  |  |
| 66 | 10.5.3 | Stage 3 - impacts MLP, RLP and PCP | 340d? | 2003-07-14 | 2004-10-29 |  |  | 2003-07-14 | 2004-10-29 | 340d? | 541d | finish no earlier than 2004-10-29 | OMA | 2720h |  | Rel-6 |  | OMA-LIAISON@mail.openmobilealliance.org |  |  |  |  |  |
| 67 | 12.7 | **UE positioning** | 958d? | 2001-01-15 A | 2004-09-15 | 85% | 141.79d? | 2000-08-28 | 2004-09-15 | 1058d? | 326d |  | RP | 18496h | 12545.8h | Rel-6 | TSG |  | LCS2-UEpos | MCC_RAN |  |  |  |
| 68 | 12.8 | Open SMLC-SRNC Interface within the UTRAN to support UTRAN Rel4 positioning methods | 700d? | 2001-01-15 A | 2003-09-19 A | 100% |  | 2001-01-15 | 2003-09-19 | 700d? |  | finish no earlier than 2003-09-19 | R2 | 5600h | 5600h | Rel-6 | TSG | Meik.Kottkamp@siemens.com | LCS-Rel4Pos |  | Meik Kottkamp, Siemens | 2475 |  |
| 69 | 10.6.2 | A-GPS minimum performance specification | 334d? | 2003-06-06 A | 2004-09-15 | 40% | 200.4d? | 2003-06-06 | 2004-09-15 | 334d? | 573d | finish no earlier than 2004-09-15 | R4 | 2672h | 1068.8h | Rel-6 | TSG | donglin.shen@attws.com | LCS-UEPos-AGPSPerf | MCC_RAN | Donglin Shen, AT&T Wireless Services |  |  |
| 70 | 12.7.2 | FS on Enhancements to OTDOA Positioning using advanced blanking methods | 320d | 2002-07-01 A | 2003-09-19 A | 100% |  | 2002-07-01 | 2003-09-19 | 320d |  | finish no earlier than 2003-09-19 | R2 | 2560h | 2560h | Rel-6 | TSG | david.bartlett@cursor-system.com | LCS2-UEpos-FSBlank |  | David Bartlett, Cambridge Positioning Systems |  |  |
| 71 | 14 | **Security enhancements** | 903d? | 2001-01-03 A | 2004-06-18 | 38% | 559.78d? | 2001-01-03 | 2004-06-18 | 903d? | 389d |  | S3 | 26984h | 9747.78h | Rel-6 | TSG | Peter.Howard@vodafone.com | SEC1 | Maurice | Peter Howard, Vodafone |  |  |
| 72 | 14.1 | **Enhanced HE control of security (including positive authentication reporting)** | 712d | 2001-01-03 A | 2003-09-25 | 23% | 545d | 2001-01-03 | 2003-09-25 | 712d | 580d |  | S3 | 14064h | 4008h | Rel-6 |  | Peter.Howard@vodafone.com |  |  | Peter Howard, Vodafone | 2026 |  |
| 73 | 14.1.1 | Stage 2 | 378d | 2001-01-03 | 2002-06-14 |  |  | 2001-01-03 | 2002-06-14 | 378d | 1161d | finish no earlier than 2002-06-14 | S3 | 3024h |  | Rel-6 |  |  |  |  |  | 2027 |  |
| 74 | 14.1.3 | **Network domain security** | 334d | 2002-06-17 A | 2003-09-25 | 50% | 167d | 2002-06-17 | 2003-09-25 | 334d | 580d |  | S3 | 5344h | 2672h | Rel-6 | TSG | Geir-myrdahl.koien@telenor.com | SEC1-NDS |  | Geir M. Køien, Telenor |  | Sec |
| 75 | 14.1.3.1 | IP network layer security (NDS/IP) | 334d | 2002-06-17 A | 2003-09-25 | 50% | 167d | 2002-06-17 | 2003-09-25 | 334d | 827d | finish no earlier than 2003-09-25 | S3 | 2672h | 1336h | Rel-6 | WG |  | SEC1-NDS-IP |  |  |  |  |
| 76 | 11.2 | Network Domain Security; Authentication Framework (NDS/AF) | 521d? | 2002-02-15 A | 2004-02-13 | 70% | 156.3d? | 2002-02-15 | 2004-02-13 | 521d? | 726d | finish no earlier than 2004-02-13 | S3 | 4168h | 2917.6h | Rel-6 | TSG | tommi.viitanen@nokia.com | SEC1-NDS-AF |  | Tommi Viitanen, Nokia |  |  |
| 77 | 11.3 | Key Management of group keys for Voice Group Call Services | 191d | 2003-09-26 A | 2004-06-18 | 5% | 181.45d | 2003-09-26 | 2004-06-18 | 191d | 636d | finish no earlier than 2004-06-18 | S3 | 1528h | 76.4h | Rel-6 | TSG | benno.tietz@vodafone.com | SECGKYV | Maurice | Benno Tietz, Vodafone D2 |  |  |

Notes:
- 56: Updated according to SP-040232
- 59: Updated according to SP-040232
- 62: Updated according to SP-040232
- 65: 31/10/2003 work has started. Current stage 3 fullfills the requirements of stage 2. ......
- 66: Updated according to SP-040232
- 68: Text3: TS25.305, 25.401, 25.450, 25.452, 25.453
- 69: Text3: TS25.171
- 71: Added BB UE authentication and rapporteur added.
- 72: Added by P-000575 without any dates. 18/10/00: Change of WI title, added hyperlink rapporteur new end date 03/01. New end date and correct Release to be decided S3#18
- 73: New end date and correct Release to be decided S3#18
- 74: WID approved for Rel-6 at SA#17
- 75: Should be complete after SA3#27 / Text3: TS 33.210
- 76: WID approved SA#19. Work started after FS approved SA#18
- 77: Approved TSG#21 / Text3: 42.068, 43.068, 44.068, 42.069, 43.069, 44.069, 31.102, 24.008, 48.008, 42.009, 43.020

| ID | WBS | Task | Duration | Start | Finish | Complete | Remaining | Baseline start | Baseline finish | Baseline duration | Total slack | Constraint | Resources | Work | Actual work | Text1 | Text3 | Text6 | Text7 | Text8 | Text4 | Text5 | Text2 | Text9 |
| --- | --- | --- | --- | --- | --- | --- | --- | --- | --- | --- | --- | --- | --- | --- | --- | --- | --- | --- | --- | --- | --- | --- | --- | --- |
| 78 | 16 | **IMS Phase 2** | 1191d? | 2000-08-28 A | 2005-03-21 | 85% | 173.58d? | 2000-08-28 | 2004-11-30 | 1112d? | 193d |  | S1 | 111139h | 89642.1h | IMS2 | 23.228 | Rel-6 | TSG | Sang-Ui |  |  |  |  |
| 79 | 12.1 | Enhancements to the Cx and Sh interfaces | 323d? | 2003-06-06 A | 2004-08-31 | 95% | 16.15d? | 2003-06-06 | 2004-08-31 | 323d? | 584d | finish no earlier than 2004-08-31 | N4 | 2584h | 2454.8h | IMS2-CCR |  | Rel-6 | WG |  |  |  |  |  |
| 80 | 16.12 | **IMS Group Management** | 715d? | 2002-03-14 A | 2004-12-08 | 88% | 85.31d? | 2002-03-14 | 2004-09-08 | 650d? | 266d |  | S1 | 12680h | 11167.1h | IMSGM |  | Rel-6 | TSG |  | Juha Kalliokulju (Nokia) | juha.kalliokulju@nokia.com |  |  |
| 81 | 16.12.1 | Stage 1 - TS on IMS group management | 193d | 2002-03-14 A | 2002-12-09 A | 100% |  | 2002-03-14 | 2002-12-09 | 193d |  | finish no earlier than 2002-12-09 | S1 | 1544h | 1544h |  |  | Rel-6 | TSG |  | Juha Kalliokulju (Nokia) | juha.kalliokulju@nokia.com |  |  |
| 82 | 12.2.2 | Stage 2 | 158d? | 2003-05-26 A | 2003-12-31 A | 100% |  | 2003-05-26 | 2003-12-31 | 158d? |  | finish no earlier than 2003-12-31 | S2 | 1264h | 1264h |  |  | Rel-6 |  |  |  |  |  |  |
| 83 | 12.2.3 | Stage 3 for IMS Group management (e.g. chat) | 519d? | 2002-12-13 A | 2004-12-08 | 80% | 103.8d? | 2002-12-13 | 2004-09-08 | 454d? | 513d | finish no earlier than 2004-12-08 | N1 | 4152h | 3321.6h |  |  |  |  |  | Keith Drage, Lucent | drage@lucent.com |  |  |
| 84 | 12.3 | **IMS Conferencing** | 548d? | 2002-11-04 A | 2004-12-08 | 91% | 51.9d? | 2002-11-04 | 2004-09-08 | 483d? | 266d |  | N1 | 10960h | 9922h |  |  | Rel-6 |  |  |  |  |  |  |
| 85 | 12.3.1 | Stage 2 | 303d? | 2002-11-04 A | 2003-12-31 A | 100% |  | 2002-11-04 | 2003-12-31 | 303d? |  | finish no earlier than 2003-12-31 | S2 | 2424h | 2424h |  |  | Rel-6 |  |  |  |  |  |  |
| 86 | 12.3.2 | Stage 3 | 519d? | 2002-12-13 A | 2004-12-08 | 85% | 77.85d? | 2002-12-13 | 2004-09-08 | 454d? | 513d | finish no earlier than 2004-12-08 | N1 | 4152h | 3529.2h |  |  |  |  |  | Keith Drage, Lucent | drage@lucent.com |  |  |
| 87 | 16.11 | **IMS Messaging** | 715d? | 2002-03-14 A | 2004-12-08 | 76% | 168.89d? | 2002-03-14 | 2004-09-08 | 650d? | 266d |  | S1 | 18560h | 14175.9h | IMSM |  | Rel-6 | TSG |  | Juha Kalliokulju (Nokia) | juha.kalliokulju@nokia.com |  |  |
| 88 | 16.11.1 | TR on support of messaging in the IMS | 193d | 2002-03-14 A | 2002-12-09 A | 100% |  | 2002-03-14 | 2002-12-09 | 193d |  | finish no earlier than 2002-12-09 | S1 | 1544h | 1544h | IMSM-TR |  | Rel-6 | TSG |  | Juha Kalliokulju (Nokia) | juha.kalliokulju@nokia.com |  |  |
| 89 | 12.4.2 | Stage 1 22.340 | 23d? | 2002-11-11 A | 2002-12-11 A | 100% |  | 2002-11-11 | 2002-12-11 | 23d? |  | finish no earlier than 2002-12-11 | S1 | 184h | 184h | IMSM-TS | 22.340 | Rel-6 | TSG |  | Juha Kalliokulju (Nokia) | juha.kalliokulju@nokia.com |  |  |
| 90 | 12.4.3 | CRs to 22.140 & 22.228 | 263d? | 2002-03-14 A | 2003-03-17 A | 100% |  | 2002-03-14 | 2003-03-17 | 263d? |  | finish no earlier than 2003-03-17 | S1 | 2104h | 2104h | IMSM-CR | 22.140,22.228 | Rel-6 | TSG |  | Juha Kalliokulju (Nokia) | juha.kalliokulju@nokia.com |  |  |
| 91 | 16.11.3 | Stage 2 | 477d | 2002-11-04 A | 2004-08-31 A | 100% |  | 2002-11-04 | 2004-08-31 | 477d |  | finish no earlier than 2004-08-31 | S2 | 3816h | 3816h |  |  | Rel-6 |  |  |  |  |  |  |
| 92 | 12.4.5 | Stage 3 for IMS Messaging | 519d? | 2002-12-13 A | 2004-12-08 | 52% | 249.12d? | 2002-12-13 | 2004-09-08 | 454d? | 513d | finish no earlier than 2004-12-08 | N1 | 4152h | 2159.04h |  |  |  |  |  | Keith Drage, Lucent | drage@lucent.com |  |  |
| 93 | 12.4.6 | SIP/SIMPLE Instant messaging | 130d? | 2004-01-01 | 2004-06-30 |  |  | 2004-01-01 | 2004-06-30 | 130d? | 628d | finish no earlier than 2004-06-30 | OMA | 1040h |  |  |  | Rel-6 | n/a |  |  | OMA-LIAISON@mail.openmobilealliance.org |  |  |
| 94 | 12.5 | **Additional SIP Capabilities support not covered by Rel-5** | 478d? | 2002-11-11 A | 2004-09-08 | 97% | 13.75d? | 2002-11-11 | 2004-09-08 | 478d? | 331d |  | N1 | 10136h | 9844.38h |  |  | Rel-6 |  |  |  |  |  |  |
| 95 | 12.5.1 | Stage 2 for add SIP cap (e.g. forking) | 335d? | 2002-11-11 A | 2004-02-20 A | 100% |  | 2002-11-11 | 2004-02-20 | 335d? |  | finish no earlier than 2004-02-20 | S2 | 2680h | 2680h |  |  | Rel-6 |  |  |  |  |  |  |
| 96 | 12.5.2 | Stage 3 for Additional SIP Capabilities | 454d? | 2002-12-13 A | 2004-09-08 | 95% | 22.7d? | 2002-12-13 | 2004-09-08 | 454d? | 578d | finish no earlier than 2004-09-08 | N1 | 3632h | 3450.4h |  |  | Rel-6 |  |  | Keith Drage, Lucent | drage@lucent.com |  |  |
| 97 | 12.6 | Review additional SIP Capabilities against IMS | 454d? | 2002-12-13 A | 2004-09-08 A | 100% |  | 2002-12-13 | 2004-03-12 | 326d? |  | finish no earlier than 2004-09-08 | N1 | 3632h | 3632h |  |  | Rel-6 |  |  | Keith Drage, Lucent | drage@lucent.com |  |  |
| 98 | 16.5 | **Interworking between IMS and IP networks** | 1118d? | 2000-08-28 A | 2004-12-08 | 88% | 131.76d? | 2000-08-28 | 2004-09-10 | 1055d? | 266d |  | N3 | 31712h | 22204.8h | IMS-CCR-IWIP | 23.821, 29.061, 29.162 | Rel-6 | TSG |  | Nigel Holland, BT | nigel.holland@bt.com | BaAS | 2048 |
| 99 | 16.5.1 | Interworking for 3GPP_SIP and IETF_SIP | 730d | 2000-08-28 A | 2003-06-13 A | 100% |  | 2000-08-28 | 2003-06-13 | 730d |  | finish no earlier than 2003-06-13 | N3 | 5840h | 5840h |  | New TR 29.962 | Rel-6 |  |  | Thomas Belling, Siemens |  |  |  |
| 100 | 16.5.2 | Interworking for IPv6 to IPv4 | 1118d | 2000-08-28 A | 2004-12-08 | 70% | 335.4d | 2000-08-28 | 2004-09-10 | 1055d | 266d | finish no earlier than 2004-12-08 | N3 | 8944h | 6260.8h |  | 29.163 | Rel-6 |  |  |  |  |  |  |
| 101 | 12.7.3 | Interworking for IPv6 to IPv4 (SIP / SDP aspects) | 87d? | 2004-05-11 A | 2004-09-08 A | 100% |  | 2004-05-11 | 2004-09-08 | 87d? |  | finish no earlier than 2004-09-08 | N1 | 696h | 696h |  |  | Rel-6 |  |  |  |  |  |  |
| 102 | 16.8.1 | stage 3 of interworking with non-IMS IP networks | 911d | 2001-03-14 A | 2004-09-08 A | 100% |  | 2001-03-14 | 2004-09-08 | 911d |  | finish no earlier than 2004-09-08 | N1 | 7288h | 7288h |  |  | Rel-6 |  |  |  |  |  |  |
| 103 | 16.6.1 | Interworking between IMS and CS networks | 929d? | 2000-08-28 A | 2004-03-18 A | 100% |  | 2000-08-28 | 2004-03-18 | 929d? |  | finish no earlier than 2004-03-18 | N3 | 7432h | 7432h | IMS-CCR-IWCS | 29.163, 29.061, 24.228, and new CN4 specification | Rel-6 | TSG |  | Brendan Mc Williams, Vodafone | brendan.mcwilliams@vf.vodafone.co.uk | CCaR |  |
| 104 | 16.10 | Mn interface (IM-MGW to MGCF) enhancements (CN4 Part) | 418d | 2001-08-07 A | 2004-09-01 | 85% | 62.7d | 2001-08-07 | 2004-09-01 | 418d | 583d | finish no earlier than 2004-09-01 | N4 | 3344h | 2842.4h | IMS-CCR-Mn |  | Rel-6 |  |  |  |  |  |  |
| 105 | 12.10 | Study of subscriber and operators relationship in IMS and related ISIM requirements for Rel 6” | 20d? | 2002-11-15 A | 2002-12-12 A | 100% |  | 2002-11-15 | 2002-12-12 | 20d? |  | finish no earlier than 2002-12-12 | S1 | 160h | 160h |  |  | Rel-6 |  |  | Juha Kalliokulju (Nokia) | juha.kalliokulju@nokia.com |  |  |
| 106 | 12.11 | Lawful Interception in the 3GPP Rel-6 architecture | 269d? | 2002-12-09 A | 2003-12-18 | 10% | 242.1d? | 2002-12-09 | 2003-12-18 | 269d? | 767d | finish no earlier than 2003-12-18 | S3 | 2152h | 215.2h | SEC1-LI | 33.106, 33.107, 33.108 | Rel-6 | TSG |  | Berthold Wilhelm | Berthold.Wilhelm@REGTP.DE |  |  |
| 107 | 12.12 | IMS Subscription and access scenarios | 130d? | 2002-12-16 A | 2003-06-13 A | 100% |  | 2002-12-16 | 2003-06-13 | 130d? |  | start no earlier than 2002-12-16 | S1 | 1040h | 1040h |  | 22.800 | Rel-6 |  |  |  |  |  |  |

Notes:
- 78: Not yet available: verbally approved at SA15, actual WID to be provided at SA16 by Lucent
- 79: 29/05/2003 CN4: New WID presented for approval at CN#20...............
- 93: Updated according to SP-040232
- 98: [DAB 14.02.02] - end date pushed back to March 2003
- 99: [DAB - 20.08.03] - CN Part of TR Complete @ CN#20
- 103: [DAB - 25.05.04] - CN3 consider this work to be complete
- 104: [CN4] 17th May 2002, CN4; Will be handled in Rel-6............

| ID | WBS | Task | Duration | Start | Finish | Complete | Remaining | Baseline start | Baseline finish | Baseline duration | Total slack | Constraint | Resources | Work | Actual work | Text1 | Text6 | Text7 | Text8 | Text3 | Text4 | Text5 | Text2 | Text9 |
| --- | --- | --- | --- | --- | --- | --- | --- | --- | --- | --- | --- | --- | --- | --- | --- | --- | --- | --- | --- | --- | --- | --- | --- | --- |
| 108 | 12.13 | **IMS enhancement for NGN** | 206d? | 2004-06-07 A | 2005-03-21 |  | 206d? | 2003-06-06 | 2004-08-31 | 323d? | 193d |  | S2 | 1419.2h |  | IMS-NGN | Rel-7 | WG | Sang-Ui |  |  |  |  |  |
| 109 | 12.13.1 | Stage 2 | 12.2d? | 2004-06-07 A | 2005-03-21 |  | 12.2d? | 2003-06-06 | 2004-08-31 | 323d? | 0d | finish no earlier than 2005-03-21 | S2 | 97.6h |  | IMS-NGN | Rel-7 | WG | Sang-Ui |  |  |  |  |  |
| 110 | 12.13.2 | Protocol impact from providing IMS services via fixed broadband | 153d? | 2004-08-03 | 2005-03-03 |  |  |  |  |  | 452d | finish no earlier than 2005-03-03 | N1 | 1224h |  |  | Rel-7 | WG | Andrijana | new TR, 24.229, 29.229, 29.163, 29.209 | Siemens |  |  |  |
| 111 | 13 | **3GPP Enablers for services like Push to Talk over Cellular (PoC)** | 344d? | 2003-09-08 A | 2004-12-30 | 40% | 205.3d? | 2003-09-08 | 2004-12-30 | 344d? | 250d |  | S2 | 7416h | 2990.06h | PoC | R6/R7? | TSG | Sang-Ui | 23.979 | Shabnam Sultana, Ericsson |  |  |  |
| 112 | 13.1 | Feasibility Study | 322d? | 2003-09-08 A | 2004-11-30 | 73% | 86.94d? | 2003-09-08 | 2004-11-30 | 322d? | 519d | finish no earlier than 2004-11-30 | S2 | 2576h | 1880.48h | PoC | R6/R7? |  |  | 23.979 | Shabnam Sultana, Ericsson |  |  |  |
| 113 | 13.2 | Dependencies on OMA PoC | 261d? | 2004-01-01 | 2004-12-30 |  |  | 2004-01-01 | 2004-12-30 | 261d? | 497d | finish no earlier than 2004-12-30 | OMA | 2088h |  | PoC | R6/R7? | n/a |  |  |  | OMA-LIAISON@mail.openmobilealliance.org |  |  |
| 114 | 14 | Interworking aspects and migration scenarios for IPv4 based IMS Implementations (Study) | 210d? | 2003-09-08 A | 2004-06-25 A | 100% |  | 2003-09-08 | 2004-06-25 | 210d? |  | finish no earlier than 2004-06-25 | S2 | 1680h | 1680h | IPv4IMS | Rel-6 |  | Sang-Ui | 23.881 | Alexander Milinski, Siemens |  |  |  |
| 115 | 16.3 | **Interoperability and Commonality between IMS using different "IP-connectivity Networks"** | 325d? | 2002-09-16 A | 2003-12-12 A | 100% |  | 2002-09-16 | 2003-12-12 | 325d? |  |  | S2 | 9176h | 9176h | IMSCOOP | Rel-6 | TSG | Sang-Ui | 23.864 |  |  |  |  |
| 116 | 16.3.1 | Stage 2 for Interoperability (no contributions assumed that no more will be done in 3GPP hence work may need to be done in pp2) | 272d | 2002-09-16 A | 2003-09-30 A | 100% |  | 2002-09-16 | 2003-09-30 | 272d |  | finish no earlier than 2003-09-30 | S2 | 2176h | 2176h |  | Rel-6 |  |  | 23.864 | Balazs Beternyi, Nokia |  |  |  |
| 117 | 15.2 | Stage 2 for commonality | 265d? | 2002-09-16 A | 2003-09-19 A | 100% |  | 2002-09-16 | 2003-09-19 | 265d? |  | start no earlier than 2002-09-16 | S2 | 2120h | 2120h |  | Rel-6 |  |  | 23.864 | Balazs Beternyi, Nokia |  |  |  |
| 118 | 16.3.2 | Stage 3 | 305d | 2002-10-14 A | 2003-12-12 A | 100% |  | 2002-10-14 | 2003-12-12 | 305d |  | finish no earlier than 2003-12-12 | N1 | 2440h | 2440h |  | Rel-6 |  |  |  | Keith Drage, Lucent | drage@lucent.com |  |  |
| 119 | 16 | **Support of Push Services** | 823d | 2001-01-03 A | 2004-02-27 | 99% | 0d | 2001-01-03 | 2004-02-27 | 823d | 0d |  | S1 | 11390.6h | 5744h | PUSH | Rel-6 | TSG | Sang-Ui | 23.976 | Yoshinori Kitada, NTT Comware |  | CCaR | 1365 |
| 120 | 16.1 | Stage 1 | 378d | 2001-01-03 A | 2002-06-14 A | 100% |  | 2001-01-03 | 2002-06-14 | 378d |  | finish no earlier than 2002-06-14 | S1 | 3024h | 3024h |  | Rel-6 |  |  |  |  |  |  |  |
| 121 | 17.3 | TR 23.976 on Push Architecture | 340d | 2002-11-11 A | 2004-02-27 A | 100% |  | 2002-11-11 | 2004-02-27 | 340d |  | finish no earlier than 2004-02-27 | S2 | 2720h | 2720h |  | Rel-6 |  |  | 23.976 | Nick Alfano, RIM |  |  |  |
| 122 | 17 | **Multimedia Messaging (MMS) enhancements** | 611d? | 2002-08-15 A | 2004-12-16 | 72% | 172.66d? | 2002-08-15 | 2004-09-16 | 546d? | 260d |  | T2 | 25718.8h | 19097.5h | MMS6 | Rel-6 | TSG | Friedhelm |  | Josef Laumen, Siemens | Josef.Laumen@SAL.SIEMENS.DE | Mes |  |
| 123 | 17.1 | **Definition of service requirements** | 286d? | 2002-11-15 A | 2003-12-19 A | 100% |  | 2002-11-15 | 2003-12-19 | 286d? |  |  | S1 | 4576h | 4576h | MMS6-SR | Rel-6 |  |  | 22.140 |  |  |  |  |
| 124 | 17.1.1 | Definition of service requirements charging | 286d? | 2002-11-15 A | 2003-12-19 A | 100% |  | 2002-11-15 | 2003-12-19 | 286d? |  | finish no earlier than 2003-12-20 | S1 | 2288h | 2288h |  | Rel-6 |  |  | 22.140 | Josef Laumen, Siemens | Josef.Laumen@SAL.SIEMENS.DE |  |  |
| 125 | 17.2 | Technical realization | 591d | 2002-09-06 A | 2004-12-10 | 80% | 118.2d | 2002-09-06 | 2004-09-10 | 526d | 511d | finish no earlier than 2004-12-10 | T2 | 4728h | 3782.4h |  | Rel-6 | TSG | Friedhelm | 23.140 | Josef Laumen, Siemens | Josef.Laumen@SAL.SIEMENS.DE |  |  |
| 126 | 17.3 | OMA dependencies | 303.85d | 2003-08-15 A | 2004-12-10 | 30% | 212.69d | 2003-08-15 | 2004-08-27 | 228.85d | 511d | finish no earlier than 2004-12-10 | T2 | 2430.8h | 729.24h |  | Rel-6 | n/a | Friedhelm | OMA specs |  |  |  |  |
| 127 | 17.4 | MMS formats and codecs | 611d | 2002-08-15 A | 2004-12-16 | 90% | 61.1d | 2002-08-15 | 2004-09-16 | 546d | 507d | finish no earlier than 2004-12-16 | S4 | 4888h | 4399.2h | MMS6-Codec | Rel-6 |  | Paolo | 26.140 | Roberto Castagno (Nokia) | roberto.castagno@nokia.com |  |  |
| 128 | 17.5 | Handling of private addressing schemes in MMS | 263d | 2003-12-10 A | 2004-12-10 | 70% | 78.9d | 2003-12-10 | 2004-06-04 | 128d | 511d | finish no earlier than 2004-12-10 | T2 | 2104h | 1472.8h |  | Rel-6 | TSG | Friedhelm | 23.140 | Matthias Röbke, T-Mobile | Matthias.Roebke@t-mobile.de |  |  |
| 129 | 17.6 | FS Multiple MMS Relay/Server Architecture | 263d | 2003-12-10 A | 2004-12-10 | 30% | 184.1d | 2003-12-10 | 2004-06-04 | 128d | 511d | finish no earlier than 2004-12-10 | T2 | 2104h | 631.2h |  | Rel-6 | TSG | Friedhelm | probably Annex to 23.140 | Juan Gorospe, Telefónica Móviles | gorospe_j@tsm.es |  |  |
| 130 | 18 | **Rel-6 MExE enhancements** | 326d | 2002-03-08 A | 2003-06-06 A | 100% |  | 2002-03-08 | 2003-06-06 | 326d |  |  | T2 | 7328h | 7328h | MEXE6 | Rel-6 | TSG | Friedhelm |  |  |  | Ter |  |
| 131 | 18.1 | MExE Rel-6 Improvements and Investigations | 264d | 2002-03-08 A | 2003-03-12 A | 100% |  | 2002-03-08 | 2003-03-12 | 264d |  | finish no earlier than 2003-03-12 | T2 | 2112h | 2112h | MEXE6-ENHANC | Rel-6 | TSG |  | 22.057, 23.057 | Lars Brenk (TTPCom) | lsb_ttpcom@HOTMAIL.COM | Ter |  |
| 132 | 18.2 | MExE Run-Time Independent Framework Feasibility Study | 326d | 2002-03-08 A | 2003-06-06 A | 100% |  | 2002-03-08 | 2003-06-06 | 326d |  | finish no earlier than 2003-06-06 | T2 | 2608h | 2608h | MEXE6-RTIF | Rel-6 | TSG |  | 22.857 | Aaron Cohen (Intel) | Aaron.Cohen@intel.com | Ter |  |
| 133 | 21 | Subscription Management | 585d | 2002-09-20 A | 2004-12-16 | 95% | 29.25d | 2002-09-20 | 2004-09-16 | 520d | 507d | finish no earlier than 2004-12-16 | S5 | 4680h | 4446h | SuM | Rel-6 | TSG | Adrian | 32.140/1, 32.171/2/3, 32.803 | Istvan ABA (T-Mobile Austria) | istvan.aba@t-mobile.at |  |  |

Notes:
- 110: WI sent to NP#25 for approval
- 113: Updated according to SP-040232
- 119: AS: Changed from FS to actual support of Push
- 129: originally it was intended to create a FS TR but most likely the work will become an Annex of 23.140
- 133: TSG#25: FOR Approval 32.172, 32.803. Remaining for 12/04 approval 32.173 CORBA SS.

| ID | WBS | Task | Duration | Start | Finish | Complete | Remaining | Baseline start | Baseline finish | Baseline duration | Total slack | Constraint | Resources | Work | Actual work | Text1 | Text4 | Text6 | Text7 | Text8 | Text9 | Text5 | Text3 |
| --- | --- | --- | --- | --- | --- | --- | --- | --- | --- | --- | --- | --- | --- | --- | --- | --- | --- | --- | --- | --- | --- | --- | --- |
| 134 | 22 | **Presence Capability** | 979d? | 2001-03-19 A | 2004-12-16 | 51% | 481.25d? | 2001-03-19 | 2004-12-31 | 990d? | 260d |  | S1 | 33208h | 16883.8h | PRESNC | Mark Cataldo, Motorola | Rel-6 | TSG | Michael | 11004 |  |  |
| 135 | 22.1 | Stage 1 | 610d | 2001-03-19 A | 2003-07-18 A | 100% |  | 2001-03-19 | 2003-07-18 | 610d |  | finish no earlier than 2003-07-18 | S1 | 4880h | 4880h |  |  | Rel-6 |  |  | 11005 |  |  |
| 136 | 22.2 | Stage 2 | 268d | 2001-09-12 A | 2002-09-20 A | 100% |  | 2001-09-12 | 2002-09-20 | 268d |  | finish no earlier than 2002-09-20 | S2 | 2144h | 2144h |  | Balazs BERTENYI, Nokia | Rel-6 | TSG |  |  | Balazs.Bertenyi@nokia.com |  |
| 137 | 22.3 | Stage 3 | 703d | 2002-04-01 A | 2004-12-08 | 91% | 63.27d | 2002-04-01 | 2004-09-08 | 638d | 513d | finish no earlier than 2004-12-08 | N1 | 5624h | 5117.84h |  | Keith Drage, Lucent | Rel-6 |  |  |  | drage@lucent.com |  |
| 138 | 20.4 | Stage 3 (CN3 Part Pk interface) | 703d? | 2002-04-01 | 2004-12-08 |  |  | 2002-04-01 | 2004-09-08 | 638d? | 266d | finish no earlier than 2004-12-08 | N3 | 5624h |  |  |  | Rel-6 |  |  |  |  |  |
| 139 | 20.5 | Media Codecs and Formats for IMS Messaging and Presence | 396d? | 2003-06-12 A | 2004-12-16 | 20% | 316.8d? | 2003-06-12 | 2004-09-16 | 331d? | 507d | finish no earlier than 2004-12-16 | S4 | 3168h | 633.6h | PRESNC-COFIMP | Harri Honko (Nokia) | Rel-6 | TSG | Paolo |  | harri.honko@nokia.com | TS 26.141 |
| 140 | 22.4 | Security issues | 79d | 2002-08-26 A | 2002-12-12 | 20% | 63.2d | 2002-08-26 | 2002-12-12 | 79d | 1032d | finish no earlier than 2002-12-12 | S3 | 632h | 126.4h |  |  | Rel-6 |  |  |  |  |  |
| 141 | 22.5 | DELETE - USIM issues | 79d | 2002-03-04 | 2002-06-20 |  |  | 2002-03-04 | 2002-06-20 | 79d | 1157d | start no earlier than 2002-03-04 | T3 | 632h |  |  |  | Rel-6 |  |  |  |  |  |
| 142 | 20.8 | DELETE - TR on Presence and Availability Management | 95d | 2004-05-03 | 2004-09-10 |  |  | 2004-05-03 | 2004-12-31 | 175d | 576d | finish no earlier than 2004-09-10 | N5 | 760h |  |  |  | Rel-6 | TSG |  |  |  | 29.998-14 |
| 143 | 20.9 | SIMPLE Presence | 239d? | 2004-01-01 | 2004-11-30 |  |  | 2004-01-01 | 2004-11-30 | 239d? | 519d | finish no earlier than 2004-11-30 | OMA | 1912h |  |  |  | Rel-6 | n/a |  |  | OMA-LIAISON@mail.openmobilealliance.org |  |
| 144 | 25 | **Enhanced A/Gb feasibility study** | 51d? | 2002-08-30 A | 2002-11-08 | 75% | 12.75d? | 2002-08-30 | 2002-11-08 | 51d? | 809d |  | GP | 4080h | 3162h | AGbEnFS | J-L Carrizo, Vodafone | Rel-6 | TSG | Paolo |  | jose-luis.carrizo@vodafone.co.uk |  |
| 145 | 25.1 | **Feasibility study on A/Gb enhancements** | 51d? | 2002-08-30 A | 2002-11-08 | 75% | 12.75d? | 2002-08-30 | 2002-11-08 | 51d? | 809d |  | G2 | 3672h | 2856h | AGbEnFS-FS |  | Rel-6 | TSG |  |  |  |  |
| 146 | 25.1.1 | Requirements for the support of conversational services | 51d | 2002-08-30 A | 2002-11-08 A | 100% |  | 2002-08-30 | 2002-11-08 | 51d |  | finish no earlier than 2002-11-08 | GP | 408h | 408h |  |  | Rel-6 |  |  |  |  |  |
| 147 | 21.1.2 | Identification of the different building blocks for the provision of conversational services on the existing A/Gb protocol stack | 51d? | 2002-08-30 A | 2002-11-08 A | 100% |  | 2002-08-30 | 2002-11-08 | 51d? |  | finish no earlier than 2002-11-08 | GP | 408h | 408h |  |  | Rel-6 |  |  |  |  |  |
| 148 | 21.1.3 | Outline of impact and feasibility of these building blocks and their different solutions | 51d? | 2002-08-30 A | 2002-11-08 A | 100% |  | 2002-08-30 | 2002-11-08 | 51d? |  | finish no earlier than 2002-11-08 | GP | 408h | 408h |  |  | Rel-6 |  |  |  |  |  |
| 149 | 25.1.2 | Identification of the different building blocks for the provision of conversational services on the existing A/Gb protocol stack | 51d | 2002-08-30 | 2002-11-08 |  |  | 2002-08-30 | 2002-11-08 | 51d | 1056d | finish no earlier than 2002-11-08 | G2 | 408h |  |  |  | Rel-6 |  |  |  |  |  |
| 150 | 25.1.3 | Outline of impact and feasibility of these building blocks and their different solutions | 51d | 2002-08-30 | 2002-11-08 |  |  | 2002-08-30 | 2002-11-08 | 51d | 1056d | finish no earlier than 2002-11-08 | G2 | 408h |  |  |  | Rel-6 |  |  |  |  |  |
| 151 | 25.1.4 | Impact on 3GPP architecture and requirement to co-ordinatge with other TSGs (CN, SA) | 51d | 2002-08-30 A | 2002-11-08 A | 100% |  | 2002-08-30 | 2002-11-08 | 51d |  | finish no earlier than 2002-11-08 | GP | 408h | 408h |  |  | Rel-6 |  |  |  |  |  |
| 152 | 25.1.5 | Standardisation effort | 51d | 2002-08-30 A | 2002-11-08 A | 100% |  | 2002-08-30 | 2002-11-08 | 51d |  | finish no earlier than 2002-11-08 | GP | 408h | 408h |  |  | Rel-6 |  |  |  |  |  |
| 153 | 25.1.6 | Dependency to other features | 51d | 2002-08-30 A | 2002-11-08 A | 100% |  | 2002-08-30 | 2002-11-08 | 51d |  | finish no earlier than 2002-11-08 | GP | 408h | 408h |  |  | Rel-6 |  |  |  |  |  |
| 154 | 26 | **Flexible Layer One for GERAN** | 1270d | 2000-01-03 A | 2004-11-12 | 93% | 83.34d | 2000-01-03 | 2004-06-25 | 1170d | 284d |  | GP | 81983h | 61035.7h | FLOGER | Benoist Sébire | Rel-6 | TSG | Paolo |  | benoist.sebire@nokia.com |  |
| 155 | 26.1 | **Realisation of a Flexible Layer One** | 1125d | 2000-01-03 A | 2004-04-23 A | 100% |  | 2000-01-03 | 2004-04-23 | 1125d |  |  | GP | 42808h | 42808h | FLOGER-Real | Benoist Sébire | Rel-6 |  |  |  | benoist.sebire@nokia.com |  |
| 156 | 26.1.1 | Technical Report | 471d | 2002-04-19 A | 2004-02-06 A | 100% |  | 2002-04-19 | 2004-02-06 | 471d |  | finish no earlier than 2004-02-06 | GP | 3768h | 3768h |  |  | Rel-6 |  |  |  |  |  |
| 157 | 26.1.2 | Architecture in 45.001 and 43.051 | 526d | 2002-04-19 A | 2004-04-23 A | 100% |  | 2002-04-19 | 2004-04-23 | 526d |  | finish no earlier than 2004-04-23 | G1 | 4208h | 4208h |  |  | Rel-6 |  |  |  |  |  |
| 158 | 26.1.3 | Multiplexing in 45.002 | 526d | 2002-04-19 A | 2004-04-23 A | 100% |  | 2002-04-19 | 2004-04-23 | 526d |  | finish no earlier than 2004-04-23 | G1 | 4208h | 4208h |  |  | Rel-6 |  |  |  |  |  |
| 159 | 26.1.4 | Channel Coding in 45.003 | 526d | 2002-04-19 A | 2004-04-23 A | 100% |  | 2002-04-19 | 2004-04-23 | 526d |  | finish no earlier than 2004-04-23 | G1 | 4208h | 4208h |  |  | Rel-6 |  |  |  |  |  |
| 160 | 26.1.5 | Performance Requirements in 45.005 | 1125d | 2000-01-03 A | 2004-04-23 A | 100% |  | 2000-01-03 | 2004-04-23 | 1125d |  | finish no earlier than 2004-04-23 | G1 | 9000h | 9000h |  |  | Rel-6 |  |  |  |  |  |
| 161 | 26.1.6 | Radio subsystem link control in 45.008 | 526d | 2002-04-19 A | 2004-04-23 A | 100% |  | 2002-04-19 | 2004-04-23 | 526d |  | finish no earlier than 2004-04-23 | G1 | 4208h | 4208h |  |  | Rel-6 |  |  |  |  |  |
| 162 | 26.1.7 | Requirements in 44.004 | 526d | 2002-04-19 A | 2004-04-23 A | 100% |  | 2002-04-19 | 2004-04-23 | 526d |  | finish no earlier than 2004-04-23 | G2 | 4208h | 4208h |  |  | Rel-6 |  |  |  |  |  |

Notes:
- 134: A Sultan merged "Presence Service Enhancements" (UID31028, PRES1) to this feature as no answer was provided on why Presence and Presence Encmts had same target completion date
- 138: No Contributions so far - only requires a little work
- 139: Also for 31022 IMS Messaging
- 140: LSs handled in SA3. WID approved SA#17 Contribution at S3#25 & following e-mail discussion.
- 142: CN#24: NO resource in CN5. Companies supporting the Presence WID (NP-030302) are asked for resources. If no resource, WT should be deleted from the Presence WID / WP).
- 143: Updated according to SP-040232
- 144: Closed
- 154: Nokia, Ericsson, Siemens, Telia
- 155: Completed

| ID | WBS | Task | Duration | Start | Finish | Complete | Remaining | Baseline start | Baseline finish | Baseline duration | Total slack | Constraint | Resources | Work | Actual work | Text1 | Text4 | Text5 | Text6 | Text3 | Text8 | Text7 | Text9 |
| --- | --- | --- | --- | --- | --- | --- | --- | --- | --- | --- | --- | --- | --- | --- | --- | --- | --- | --- | --- | --- | --- | --- | --- |
| 163 | 26.2 | **Signalling and protocol support for a Flexible Layer One** | 571d | 2002-04-19 A | 2004-06-25 | 99% | 0d | 2002-04-19 | 2004-06-25 | 571d | 0d |  | G2 | 13704h | 10134.4h | FLOGER-SigPro | Benoist Sébire | benoist.sebire@nokia.com | Rel-6 |  |  |  |  |
| 164 | 26.2.1 | Modifications to RLC/MAC in 44.060 and 44.160 | 571d | 2002-04-19 A | 2004-06-25 A | 100% |  | 2002-04-19 | 2004-06-25 | 571d |  | finish no earlier than 2004-06-25 | G2 | 4568h | 4568h |  |  |  | Rel-6 |  |  |  |  |
| 165 | 26.2.2 | Modifications to RRC in 44.118 and 44.018 | 571d | 2002-04-19 A | 2004-06-25 A | 100% |  | 2002-04-19 | 2004-06-25 | 571d |  | finish no earlier than 2004-06-25 | G2 | 4568h | 4568h |  |  |  | Rel-6 |  |  |  |  |
| 166 | 26.3 | **Security for a Flexible Layer One** | 356d | 2002-04-19 A | 2003-08-29 A | 100% |  | 2002-04-19 | 2003-08-29 | 356d |  |  | S3, G2 | 5663.04h | 5663.04h | FLOGER-SecFLO | Benoist Sébire | benoist.sebire@nokia.com | Rel-6 |  |  |  |  |
| 167 | 26.3.1 | Ciphering in 44.160,44.118, 44.060 and 44.018 | 356d | 2002-04-19 A | 2003-08-29 A | 100% |  | 2002-04-19 | 2003-08-29 | 356d |  | finish no earlier than 2003-08-29 | S3, G2 | 2848h | 2848h |  |  |  | Rel-6 |  |  |  |  |
| 168 | 26.4 | **GERAN MS Conformance test for the Flexible Layer One** | 201d | 2004-02-06 | 2004-11-12 |  |  | 2004-02-06 | 2004-06-25 | 101d | 284d |  | G4; G5 | 6432h |  | FLOGER-Msconf | Benoist Sébire | benoist.sebire@nokia.com | Rel-6 |  |  |  |  |
| 169 | 26.4.1 | MS Test in 51.010 | 201d | 2004-02-06 | 2004-11-12 |  |  | 2004-02-06 | 2004-06-25 | 101d | 531d | finish no earlier than 2004-11-12 | G4; G5 | 3216h |  |  |  |  | Rel-6 |  |  |  |  |
| 170 | 26.5 | **GERAN BTS Conformance test for the Flexible Layer One** | 201d | 2004-02-06 | 2004-11-12 |  |  | 2004-02-06 | 2004-06-25 | 101d | 284d |  | G3 | 3216h |  | FLOGER-BTSconf | Benoist Sébire | benoist.sebire@nokia.com | Rel-6 |  |  |  |  |
| 171 | 26.5.1 | BTS Test in 51.021 | 201d | 2004-02-06 | 2004-11-12 |  |  | 2004-02-06 | 2004-06-25 | 101d | 531d | finish no earlier than 2004-11-12 | G3 | 1608h |  |  |  |  | Rel-6 |  |  |  |  |
| 172 | 27 | Uplink TDOA feasibility study | 151d | 2001-11-30 A | 2002-06-28 A | 100% |  | 2001-11-30 | 2002-06-28 | 151d |  | finish no earlier than 2002-06-28 | GP | 1208h | 1208h | TDOAF | Bob Gross, TruePosition, Inc. | rlgross@trueposition.com | Rel-6 | 45.811 | Paolo |  |  |
| 173 | 28 | **Multimedia Broadcast and Multicast Service** | 940d? | 2001-05-11 A | 2004-12-16 | 57% | 400.05d? | 2001-05-11 | 2004-12-16 | 940d? | 260d |  | S1 | 108570h | 54671.4h | MBMS |  |  | Rel-6 |  | Michael | TSG |  |
| 174 | 28.1 | Stage 1 | 232d | 2001-05-11 A | 2002-04-01 A | 100% |  | 2001-05-11 | 2002-04-01 | 232d |  | finish no earlier than 2002-04-01 | S1 | 1856h | 1856h |  |  |  | Rel-6 | 22.146, 22.101 |  |  | 11003 |
| 175 | 28.2 | **Stage 2** | 648d | 2001-09-24 A | 2004-03-17 | 99% | 0d | 2001-09-24 | 2004-03-17 | 648d | 0d |  | S2 | 10408h | 6548.8h |  |  |  | Rel-6 |  |  | TSG |  |
| 176 | 28.2.1 | TR on Architectural Study | 240d | 2001-09-24 A | 2002-08-23 A | 100% |  | 2001-09-24 | 2002-08-23 | 240d |  | finish no earlier than 2002-08-23 | S2 | 1920h | 1920h |  |  |  | Rel-6 | 23.846 |  |  |  |
| 177 | 28.2.2 | Stage 2 Specification Work. (User Service aspects may impact) (progress will be check in Friday of S2 #38 !!) | 413d | 2002-08-19 A | 2004-03-17 A | 100% |  | 2002-08-19 | 2004-03-17 | 413d |  | finish no earlier than 2004-03-17 | S2 | 3304h | 3304h |  |  |  | Rel-6 | 23.246 |  |  |  |
| 178 | 28.3 | Introduction of MBMS in RAN | 771d | 2002-01-01 A | 2004-12-15 | 80% | 154.2d | 2002-01-01 | 2004-09-15 | 707d | 509d | finish no earlier than 2004-12-15 | R2 | 6168h | 4934.4h | MBMS-RAN | Juho Pirskanen , Nokia | juho.pirskanen@nokia.com | Rel-6 | TS 25.346, TS 25.304, 25.321, 25.322, 25.323, 25.331 | MCC_RAN | TSG | 2481 |
| 179 | 28.4 | Support of the MBMS in CN protocols | 647d | 2002-06-18 A | 2004-12-08 | 90% | 64.7d | 2002-06-18 | 2004-09-08 | 582d | 513d | finish no earlier than 2004-12-08 | N1 | 5176h | 4658.4h |  |  |  | Rel-6 |  |  | TSG |  |
| 180 | 24.5 | Gmb interface for MBMS (CN3 part) | 334d | 2003-08-29 A | 2004-12-08 | 85% | 50.1d | 2003-08-29 | 2004-09-10 | 271d | 266d | finish no earlier than 2004-12-08 | N3 | 2672h | 2271.2h |  |  |  | Rel-6 | 29.061 |  |  |  |
| 181 | 28.5 | Security Aspects of Multimedia Broadcast/Multicast Service (MBMS) | 324d | 2002-07-01 A | 2003-09-25 | 20% | 259.2d | 2002-07-01 | 2003-09-25 | 324d | 827d | finish no earlier than 2003-09-25 | S3 | 2592h | 518.4h | MBMS | Escott, Adrian, 3 | adrian.escott@three.co.uk | Rel-6 |  |  | TSG |  |
| 182 | 28.6 | **Support of MBMS in GERAN** | 837d? | 2001-08-30 A | 2004-11-12 | 46% | 450.93d? | 2001-08-30 | 2004-11-12 | 837d? | 284d |  | GP | 64080h | 27617.5h | MBMS-GERAN |  |  | Rel-6 |  |  | TSG |  |
| 183 | 28.6.1 | Impact on the logical and physical channels | 576d | 2002-08-30 A | 2004-11-12 | 50% | 288d | 2002-08-30 | 2004-11-12 | 576d | 531d | finish no earlier than 2004-11-12 | GP | 4608h | 2304h |  |  |  | Rel-6 |  |  |  |  |
| 184 | 28.6.4 | Re-synchronisation at cell change | 576d | 2002-08-30 A | 2004-11-12 | 50% | 288d | 2002-08-30 | 2004-11-12 | 576d | 531d | finish no earlier than 2004-11-12 | G2 | 4608h | 2304h |  |  |  | Rel-6 |  |  |  |  |
| 185 | 24.7.3 | Simultaneous support of MBMS services | 576d? | 2002-08-30 A | 2004-11-12 | 50% | 288d? | 2002-08-30 | 2004-11-12 | 576d? | 531d | finish no earlier than 2004-11-12 | GP | 4608h | 2304h |  |  |  | Rel-6 |  |  |  |  |
| 186 | 24.7.4 | Simultaneous support of MBMS and non-MBMS services | 837d? | 2001-08-30 A | 2004-11-12 | 50% | 418.5d? | 2001-08-30 | 2004-11-12 | 837d? | 531d | finish no earlier than 2004-11-12 | GP | 6696h | 3348h |  |  |  | Rel-6 |  |  |  |  |
| 187 | 24.7.5 | Resynchronisation at cell change | 837d? | 2001-08-30 A | 2004-11-12 | 50% | 418.5d? | 2001-08-30 | 2004-11-12 | 837d? | 531d | finish no earlier than 2004-11-12 | GP | 6696h | 3348h |  |  |  | Rel-6 |  |  |  |  |
| 188 | 28.6.5 | Decision making process between point-to-point or pont-to-multipoint configurations | 576d | 2002-08-30 A | 2004-11-12 | 50% | 288d | 2002-08-30 | 2004-11-12 | 576d | 531d | finish no earlier than 2004-11-12 | GP | 4608h | 2304h |  |  |  | Rel-6 |  |  |  |  |
| 189 | 28.6.6 | MBMS channel allocations procedures to multiple MSs | 576d | 2002-08-30 A | 2004-11-12 | 50% | 288d | 2002-08-30 | 2004-11-12 | 576d | 531d | finish no earlier than 2004-11-12 | GP | 4608h | 2304h |  |  |  | Rel-6 |  |  |  |  |
| 190 | 28.6.7 | Changes to the Gb interface | 576d | 2002-08-30 A | 2004-11-12 | 50% | 288d | 2002-08-30 | 2004-11-12 | 576d | 531d | finish no earlier than 2004-11-12 | GP | 4608h | 2304h |  |  |  | Rel-6 |  |  |  |  |
| 191 | 28.6.8 | GERAN specific changes to the Iu-ps interface | 576d | 2002-08-30 A | 2004-11-12 | 50% | 288d | 2002-08-30 | 2004-11-12 | 576d | 531d | finish no earlier than 2004-11-12 | GP | 4608h | 2304h |  |  |  | Rel-6 |  |  |  |  |
| 192 | 28.6.9 | Interaction between MBMS and Iu-flex | 576d | 2002-08-30 A | 2004-11-12 | 50% | 288d | 2002-08-30 | 2004-11-12 | 576d | 531d | finish no earlier than 2004-11-12 | GP | 4608h | 2304h |  |  |  | Rel-6 |  |  |  |  |
| 193 | 28.6.10 | Security aspects | 576d | 2002-08-30 A | 2004-11-12 | 50% | 288d | 2002-08-30 | 2004-11-12 | 576d | 531d | finish no earlier than 2004-11-12 | GP | 4608h | 2304h |  |  |  | Rel-6 |  |  |  |  |
| 194 | 24.7.12 | MS conformance tests- G3 | 576d? | 2002-08-30 | 2004-11-12 |  |  | 2002-08-30 | 2004-11-12 | 576d? | 531d | finish no earlier than 2004-11-12 | G3 | 4608h |  |  |  |  | Rel-6 |  |  |  |  |

Notes:
- 163: Completed
- 166: Started
- 168: Not started
- 170: Not started
- 173: Title renamed at SA#13
- 174: This may or may not be a separate stage 1. In the meantime, CRs are proposed for 22.101
- 181: WID approved SA#17

| ID | WBS | Task | Duration | Start | Finish | Complete | Remaining | Baseline start | Baseline finish | Baseline duration | Total slack | Constraint | Resources | Work | Actual work | Text3 | Text6 | Text8 | Text9 | Text1 | Text4 | Text5 | Text7 |
| --- | --- | --- | --- | --- | --- | --- | --- | --- | --- | --- | --- | --- | --- | --- | --- | --- | --- | --- | --- | --- | --- | --- | --- |
| 195 | 28.1 | **MBMS User Services** | 418d? | 2003-05-13 A | 2004-12-16 | 75% | 105.26d? | 2003-05-13 | 2004-12-16 | 418d? | 260d |  | S1 | 8376h | 6266.69h | 22.246 | Rel-6 | Michael | 11003 |  |  |  |  |
| 196 | 28.1 | MBMS User Services Stage 1 | 233d | 2003-05-13 A | 2004-04-01 A | 100% |  | 2003-05-13 | 2004-04-01 | 233d |  | start no earlier than 2003-05-13 | S1 | 1864h | 1864h | 22.246 | Rel-6 | Michael | 11003 |  |  |  |  |
| 197 | 24.8.2 | Definition of MBMS user services, media codecs, formats and transport/application protocols using MBMS | 396d? | 2003-06-12 A | 2004-12-16 | 60% | 158.4d? | 2003-06-12 | 2004-12-16 | 396d? | 507d | finish no earlier than 2004-12-16 | S4 | 3168h | 1900.8h | 26.346 | Rel-6 | Paolo |  | MBMS-TSMBMS | Igor Curcio (Nokia) | igor.curcio@nokia.com | TSG |
| 198 | 29 | **Speech Recognition and Speech Enabled Services** | 834d? | 2001-10-08 A | 2004-12-16 | 97% | 27.37d? | 2001-10-08 | 2004-06-10 | 699d? | 260d |  | S1 | 13840h | 13385.9h |  | Rel-6 | Michael |  | SRSES |  |  | TSG |
| 199 | 29.1 | Speech Enabled Services Based on Distributed Speech Recognition (DSR) | 115d | 2001-10-08 A | 2002-03-15 A | 100% |  | 2001-10-08 | 2002-03-15 | 115d |  | finish no earlier than 2002-03-15 | S1 | 920h | 920h | 22.941, 23.207, 22.243 | Rel-6 |  |  | DSR | D Williams, QUALCOMM, Inc. | Dwilliams@qualcomm.com | TSG |
| 200 | 29.2 | TR on Architectural impacts | 212d | 2003-05-12 A | 2004-03-02 A | 100% |  | 2003-05-12 | 2004-03-02 | 212d |  | finish no earlier than 2004-03-02 | S2 | 1696h | 1696h | 23.877 | Rel-6 |  |  |  |  |  |  |
| 201 | 25.3 | Codec Work to Support Speech Recognition Framework for Automated Voice Services | 568d? | 2002-10-15 A | 2004-12-16 | 95% | 28.4d? | 2002-10-15 | 2004-06-10 | 433d? | 507d | finish no earlier than 2004-12-16 | S4 | 4544h | 4316.8h | 26.235, 26.236, 26.243 | Rel-6 | Paolo |  | SRSES-Codec | David Pearce, Motorola | bdp003@motorola.com | WG |
| 202 | 25.4 | Multimodal support | 1d? | 2004-01-01 | 2004-01-01 |  |  | 2004-01-01 | 2004-01-01 | 1d? | 757d | start no earlier than 2004-01-01 | OMA | 8h |  |  | Rel-6 |  |  |  |  | OMA-LIAISON@mail.openmobilealliance.org |  |
| 203 | 30 | **Generic User Profile** | 889d | 2001-10-08 A | 2005-03-03 | 55% | 397.94d | 2001-10-08 | 2004-11-30 | 822d | 205d |  | S1 | 28983.8h | 16010h |  | Rel-6 | Michael |  | GUP |  |  | TSG |
| 204 | 30.1 | Stage 1 - Requirements | 430d | 2001-10-08 A | 2003-05-30 A | 100% |  | 2001-10-08 | 2003-05-30 | 430d |  | finish no earlier than 2002-12-09 | S1 | 3440h | 3440h | 22.240, 22.228 | Rel-6 |  |  |  | Paul Amery (Orange) | paul.amery@orange.co.uk |  |
| 205 | 30.3 | Stage 2 - Architecture | 355d | 2002-01-28 A | 2003-06-06 A | 100% |  | 2002-01-28 | 2003-06-06 | 355d |  | finish no earlier than 2003-06-06 | S2 | 2840h | 2840h | 23.240 | Rel-6 |  |  |  | Harri KOSKINEN, Nokia | harri.o.koskinen@nokia.com |  |
| 206 | 30.2 | Stage 2 - Data Description Method | 586d | 2002-12-05 A | 2005-03-03 | 45% | 322.3d | 2002-12-05 | 2004-03-05 | 327d | 452d | finish no earlier than 2005-03-03 | N4 | 4688h | 2109.6h | 23.241 | Rel-6 | Friedhelm |  |  | Kurt Bischinger (T-Mobile AUSTRIA) | kurt.bischinger@t-mobile.at | TSG |
| 207 | 30.4 | Stage 3 - Common objects | 586d | 2002-12-05 A | 2005-03-03 | 40% | 351.6d | 2002-12-05 | 2004-09-03 | 457d | 452d | finish no earlier than 2005-03-03 | N4 | 4688h | 1875.2h | 24.241 | Rel-6 | Friedhelm |  |  |  |  | TSG |
| 208 | 30.5 | Stage 3 - Network | 468.98d | 2003-05-19 A | 2005-03-03 | 39% | 288.09d | 2003-05-19 | 2004-11-30 | 401.98d | 452d | finish no earlier than 2005-03-03 | N4 | 3751.84h | 1447.13h | 29.240 | Rel-6 |  |  |  |  |  |  |
| 209 | 30.6 | Security Aspects | 308d | 2002-07-16 A | 2003-09-18 | 15% | 261.8d | 2002-07-16 | 2003-09-18 | 308d | 832d | finish no earlier than 2003-09-18 | S3 | 2464h | 369.6h | 33.102, 33.203, 33.210 | Rel-6 |  |  |  | Owen, Bradley | bvowen@lucent.com | WG |
| 210 | 31 | **Digital Rights Management** | 690d? | 2001-10-08 A | 2004-05-28 | 56% | 306.08d? | 2001-10-08 | 2004-05-28 | 690d? | 404d |  | S1 | 11392h | 6338.55h |  | Rel-6 | Michael |  | DRM |  |  | TSG |
| 211 | 31.1 | Requirements | 179d | 2001-10-08 A | 2002-06-13 A | 100% |  | 2001-10-08 | 2002-06-13 | 179d |  | finish no earlier than 2002-06-13 | S1 | 1432h | 1432h |  | Rel-6 |  |  |  | Nicholas Wood, Openwave Systems | nicholas.wood@openwave.com |  |
| 212 | 27.2 | Monitoring of Stages 2 and 3 progress (actual work to be done by OMA) | 155d? | 2002-08-19 A | 2003-03-21 A | 100% |  | 2002-08-19 | 2003-03-21 | 155d? |  | start no earlier than 2002-08-19 | S1 | 1240h | 1240h |  | Rel-6 |  |  |  |  |  |  |
| 213 | 31.3 | Monitoring of Security (work done by OMA) | 186d | 2002-06-17 A | 2003-03-03 | 40% | 111.6d | 2002-06-17 | 2003-03-03 | 186d | 975d | finish no earlier than 2003-03-03 | S3 | 1488h | 595.2h |  | Rel-6 |  |  |  |  |  |  |
| 214 | 27.4 | Stage 2 | 107d? | 2004-01-01 | 2004-05-28 |  |  | 2004-01-01 | 2004-05-28 | 107d? | 651d | finish no earlier than 2004-05-28 | OMA | 856h |  |  | Rel-6 |  |  |  |  | OMA-LIAISON@mail.openmobilealliance.org |  |
| 215 | 27.5 | Stage 3 | 107d? | 2004-01-01 | 2004-05-28 |  |  | 2004-01-01 | 2004-05-28 | 107d? | 651d | finish no earlier than 2004-05-28 | OMA | 856h |  |  | Rel-6 |  |  |  |  | OMA-LIAISON@mail.openmobilealliance.org |  |
| 216 | 32 | **WLAN-UMTS Interworking** | 1288d? | 2000-01-03 A | 2004-12-08 | 88% | 151.09d? | 2000-01-03 | 2004-09-30 | 1239d? | 266d |  | S1 | 38808h | 34363.4h |  | Rel-6 | Michael |  | WLAN | Fredric Paint, Telenor | frederic.paint@telenor.com | TSG |
| 217 | 32.1 | Technical Report | 900d? | 2000-01-03 A | 2003-06-13 A | 100% |  | 2000-01-03 | 2003-06-13 | 900d? |  | finish no earlier than 2003-06-13 | S1 | 7200h | 7200h | 22.934, 22.101, 22.105 | Rel-6 |  |  | WLAN-TR | Fredric Paint, Telenor | frederic.paint@telenor.com |  |
| 218 | 28.2 | **Stage 1** | 375d? | 2003-01-06 A | 2004-06-11 | 83% | 64.48d? | 2000-01-03 | 2004-06-11 | 1160d? | 394d |  | S1 | 4840h | 4166h | 22.234 | Rel-6 |  |  | WLAN-TS | Fredric Paint, Telenor | frederic.paint@telenor.com |  |
| 219 | 28.2.1 | Global stage 1 | 375d? | 2003-01-06 A | 2004-06-11 | 99% | 3.75d? |  |  |  | 641d | finish no earlier than 2004-06-11 | S1 | 3000h | 2970h | 22.234 | Rel-6 |  |  | WLAN-TS | Fredric Paint, Telenor | frederic.paint@telenor.com |  |
| 220 | 28.2.2 | Session Continuity | 115d? | 2004-01-05 A | 2004-06-11 | 30% | 80.5d? |  |  |  | 641d | start no earlier than 2004-01-05 | S1 | 920h | 276h |  | Rel-7 |  |  | WLAN-SC |  |  |  |
| 221 | 32.2 | Architecture Definition for scenarii 2 and 3 | 571d | 2002-03-25 A | 2004-05-31 A | 100% |  | 2002-03-25 | 2004-05-31 | 571d |  | finish no earlier than 2004-05-31 | S2 | 4568h | 4568h | 23.234 | Rel-6 |  |  |  |  |  | TSG |
| 222 | 32.3 | Security | 125d | 2002-09-30 A | 2003-03-21 | 30% | 87.5d | 2002-09-30 | 2003-03-21 | 125d | 961d | finish no earlier than 2003-03-21 | S3 | 1000h | 300h | 21.133, 33.106, 33.107, 33.108, 33.200, 33.203, 33.210 | Rel-6 |  |  |  | Lopez-Soria, Luis, Ericsson | luis.lopez-soria@ece.ericsson.se | TSG |
| 223 | 28.5 | Stage 3 - CN4 aspects | 334d? | 2003-05-23 A | 2004-09-01 | 85% | 50.1d? | 2003-05-23 | 2004-09-01 | 334d? | 583d | finish no earlier than 2004-09-01 | N4 | 2672h | 2271.2h | 29.234, 29.061 | Rel-6 |  |  | WLAN-IW | Rodriguez ,Raquel, Nokia | raquel.rodriguez@nokia.com | TSG |
| 224 | 28.6 | Stage 3 - CN3 aspects (Wi Interface for Scenario 3) | 285d? | 2003-05-23 A | 2004-09-30 | 95% | 14.25d? | 2003-05-23 | 2004-09-30 | 355d? | 315d | finish no earlier than 2004-09-30 | N3 | 2280h | 2166h | 29.161 | Rel-6 |  |  | WLAN |  |  | TSG |
| 225 | 28.7 | Stage 3 for scenario 2 | 339d? | 2003-05-23 A | 2004-09-08 | 98% | 6.78d? | 2003-05-23 | 2004-09-08 | 339d? | 578d | finish no earlier than 2004-09-08 | N1 | 2712h | 2657.76h |  | Rel-6 |  |  |  |  |  | WG |
| 226 | 28.8 | Stage 3 for scenario 3 | 404d? | 2003-05-23 A | 2004-12-08 | 60% | 161.6d? | 2003-05-23 | 2004-09-08 | 339d? | 513d | finish no earlier than 2004-12-08 | N1 | 3232h | 1939.2h |  | Rel-6 |  |  |  |  |  | WG |

Notes:
- 208: 17 May no activity in CN4............
- 209: WID approved SA#17. SA WG3 progress slow, depends on progress in other groups.
- 210: Foreseen start and completion dates introduced by MCC (no indication at all on the WID)
- 213: SA3 acknowledge role in WI at SA3#20. Active contribution S3#24, S3#25. S3 WID approved SA#17
- 222: Active contribution S3#24, S3#25. WID approved SA#17
- 223: WID approved at CN#19...............

| ID | WBS | Task | Duration | Start | Finish | Complete | Remaining | Baseline start | Baseline finish | Baseline duration | Total slack | Constraint | Resources | Work | Actual work | Text1 | Text6 | Text7 | Text8 | Text4 | Text5 | Text9 | Text10 | Text11 | Text12 |
| --- | --- | --- | --- | --- | --- | --- | --- | --- | --- | --- | --- | --- | --- | --- | --- | --- | --- | --- | --- | --- | --- | --- | --- | --- | --- |
| 227 | 33 | **Priority Service** | 666d? | 2002-05-30 A | 2004-12-16 | 76% | 162.53d? | 2002-05-30 | 2004-12-16 | 666d? | 260d |  | S1 | 12616h | 9537.26h | NTShar | Rel-6 | TSG | Michael |  |  |  |  |  |  |
| 228 | 33.1 | Feasibility Study | 1d | 2002-06-14 A | 2002-06-14 A | 100% |  | 2002-06-14 | 2002-06-14 | 1d |  | finish no earlier than 2002-06-14 | S1 | 8h | 8h | PRIOR-FS | Rel-6 |  | Michael | Biplab K. Pramanik, Telcordia Technologies | bpramani@telcordia.com |  |  |  |  |
| 229 | 33.2 | Stage 1 - Requirements | 340d | 2002-05-30 A | 2003-09-17 A | 100% |  | 2002-05-30 | 2003-09-17 | 340d |  | finish no earlier than 2003-09-17 | S1 | 2720h | 2720h | PRIOR-SR | Rel-6 |  | Michael | James J. Garrahan, Telcordia Technologies | bpramani@telcordia.com |  |  |  |  |
| 230 | 29.3 | Multimedia Priority Service | 450d? | 2003-03-28 A | 2004-12-16 | 50% | 225d? | 2003-03-28 | 2004-12-16 | 450d? | 507d | finish no earlier than 2004-12-16 | S1 | 3600h | 1800h |  | Rel-6 |  |  |  |  |  |  |  |  |
| 231 | 29.4 | Priority service implementation guide | 131d? | 2003-03-28 A | 2003-09-26 A | 100% |  | 2003-03-28 | 2003-09-26 | 131d? |  | finish no earlier than 2003-09-26 | S1 | 1048h | 1048h |  | Rel-6 |  |  | Biplab K. Pramanik, Telcordia Technologies | bpramani@telcordia.com |  |  |  |  |
| 232 | 34 | **Network Sharing** | 493d? | 2003-01-20 A | 2004-12-08 | 89% | 55.16d? | 2003-01-20 | 2005-03-17 | 563.41d? | 266d |  | S1 | 16040h | 14245.3h | NTShar | Rel-6 | TSG | Michael |  |  |  |  |  |  |
| 233 | 34.1 | Technical Report | 240d? | 2003-01-20 A | 2003-12-19 A | 100% |  | 2003-01-20 | 2003-12-19 | 240d? |  |  | S1 | 1920h | 1920h | NTShar-TR | Rel-6 |  | Michael |  |  |  |  |  |  |
| 234 | 30.2 | Stage 1 - CRs to implement Network Sharing | 240d? | 2003-01-20 A | 2003-12-19 A | 100% |  | 2003-01-20 | 2003-12-19 | 240d? |  | finish no earlier than 2003-12-19 | S1 | 1920h | 1920h | NTShar-CR | Rel-6 |  |  |  |  |  |  |  |  |
| 235 | 30.3 | Stage 2 | 372d? | 2003-02-27 A | 2004-07-30 A | 100% |  | 2003-02-27 | 2004-07-30 | 372d? |  | finish no earlier than 2004-07-30 | S2 | 2976h | 2976h |  | Rel-6 |  |  |  |  |  |  |  |  |
| 236 | 30.4 | Network sharing - stage 3 | 404d? | 2003-05-23 A | 2004-12-08 | 90% | 40.4d? | 2003-05-23 | 2004-09-08 | 339d? | 513d | finish no earlier than 2004-12-08 | N1 | 3232h | 2908.8h |  | Rel-6 | WG |  |  |  |  |  |  |  |
| 237 | 30.5 | Enhancement of the support of network sharing in the UTRAN | 258d | 2003-09-19 A | 2004-09-15 | 50% | 129d | 2003-09-19 | 2005-03-17 | 389.41d | 574d | finish no earlier than 2004-09-15 | R2 | 2064h | 1032h | NTShar-UTRANEnh | Rel-6 | TSG | MCC_RAN | Anders Dahlén, TeliaSonera | Anders.Dahlen@TeliaSonera.com | BB | 31018 | Active | 48 |
| 238 | 35 | **QoS Improvements** | 628d? | 2002-07-15 A | 2004-12-08 | 95% | 31.06d? | 2002-07-15 | 2004-09-10 | 565d? | 266d |  | S2 | 13128h | 12478.7h | QoS1 | Rel-6 | TSG | Sang-Ui |  |  |  |  |  |  |
| 239 | 35.1 | FS on Dynamic Policy control enhancements for end-to-end QoS | 465d | 2002-07-15 A | 2004-04-23 A | 100% |  | 2002-07-15 | 2004-04-23 | 465d |  | finish no earlier than 2004-04-23 | S2 | 3720h | 3720h | QoS1 | Rel-6 | TSG |  |  | Claire Mousset, Nortel |  |  |  |  |
| 240 | 31.2 | Definition of the Gq interface | 214d? | 2003-07-01 A | 2004-04-23 A | 100% |  | 2003-07-01 | 2004-04-23 | 214d? |  | finish no earlier than 2004-04-23 | S2 | 1712h | 1712h |  | Rel-6 |  |  | Janne Rinne (Nokia) |  |  |  |  |  |
| 241 | 31.3 | Gq interface specification for Dynamic Policy control enhancements – Stage 3 | 334d | 2003-08-29 A | 2004-12-08 | 85% | 50.1d | 2003-08-29 | 2004-09-10 | 271d | 266d | finish no earlier than 2004-12-08 | N3 | 2672h | 2271.2h |  | Rel-6 | TSG |  | Anna Sillanpää, Nokia | Anna.Sillanpaai@nokia.com |  |  |  |  |
| 242 | 36 | **Subscriber certificates** | 728d? | 2002-02-25 A | 2004-12-08 | 80% | 145.56d? | 2002-02-25 | 2004-11-30 | 722d? | 266d |  | S3 | 12888h | 10311.1h | SEC1-SC | Rel-6 | TSG | Maurice | Valtteri Niemi, Nokia | valtteri.niemi@nokia.com |  |  |  |  |
| 243 | 36.1 | Stage 1 | 144d | 2002-02-25 A | 2002-09-12 | 40% | 86.4d | 2002-02-25 | 2002-09-12 | 144d | 1097d | finish no earlier than 2002-09-12 | S3 | 1152h | 460.8h |  | Rel-6 |  |  |  |  |  |  |  |  |
| 244 | 36.2 | Architecture review | 24d | 2002-10-14 A | 2002-11-14 A | 100% |  | 2002-10-14 | 2002-11-14 | 24d |  | finish no earlier than 2002-11-14 | S2 | 192h | 192h |  | Rel-6 |  |  |  |  |  |  |  |  |
| 245 | 32.3 | Stage 3 | 313d? | 2003-09-19 A | 2004-11-30 | 85% | 46.95d? | 2003-09-19 | 2004-11-30 | 313d? | 519d | finish no earlier than 2004-11-30 | N4 | 2504h | 2128.4h | SEC1-SC | Rel-6 |  | Kimmo | Lauri Laitinen, Nokia |  |  |  |  |  |
| 246 | 32.4 | Stage 3 Ua & Ub interfaces | 288d? | 2003-11-03 A | 2004-12-08 | 85% | 43.2d? | 2003-11-03 | 2004-09-08 | 223d? | 513d | finish no earlier than 2004-12-08 | N1 | 2304h | 1958.4h |  | Rel-6 |  |  |  |  |  |  |  |  |
| 247 | 32.5 | OMA dependencies on Subscriber certificates | 114d? | 2004-01-01 A | 2004-06-08 A | 100% |  | 2004-01-01 | 2004-06-08 | 114d? |  | finish no earlier than 2004-06-08 | OMA | 912h | 912h |  | Rel-6 | n/a |  |  | OMA-LIAISON@mail.openmobilealliance.org |  |  |  |  |
| 248 | 33 | **Rel-6 OSA enhancements** | 552d? | 2002-10-31 A | 2004-12-10 | 81% | 104.59d? | 2002-10-31 | 2004-09-30 | 501d? | 264d |  | S1 | 25783.2h | 18680.3h | OSA3 | Rel-6 | TSG | Adrian | Chelo ABARCA (Alcatel) | Chelo.Abarca@alcatel.fr |  |  |  |  |
| 249 | 33.1 | Scope of the Open Service Access Release 6 | 66d? | 2003-03-28 A | 2003-06-27 A | 100% |  | 2003-03-28 | 2003-06-27 | 66d? |  | finish no earlier than 2003-06-27 | S1 | 528h | 528h |  | Rel-6 | TSG |  |  |  |  |  |  |  |
| 250 | 33.2 | OSA Stage 2 (CN5 inherited from SA2 at TSG#24/5) | 86d? | 2004-08-13 A | 2004-12-10 | 50% | 43d? |  |  |  | 511d | finish no earlier than 2004-12-10 | N5 | 688h | 344h |  | Rel-6 | TSG |  |  |  |  |  |  |  |
| 251 | 33.3 | Multi Media Messaging function | 487d? | 2002-10-31 A | 2004-09-10 A | 100% |  | 2002-10-31 | 2004-06-18 | 427d? |  | finish no earlier than 2004-09-10 | N5 | 3896h | 3896h |  | Rel-6 | TSG |  |  |  |  |  |  |  |
| 252 | 33.4 | Policy management extensions | 292d? | 2002-10-31 A | 2003-12-12 A | 100% |  | 2002-10-31 | 2003-12-12 | 292d? |  | finish no earlier than 2003-12-12 | N5 | 2336h | 2336h |  | Rel-6 | TSG |  |  |  |  |  |  |  |
| 253 | 33.5 | TS on Presence and Availability Management (from the PRESNC WI) | 367d? | 2002-10-31 A | 2004-03-26 A | 100% |  | 2002-10-31 | 2004-03-26 | 367d? |  | finish no earlier than 2004-03-26 | N5 | 2936h | 2936h |  | Rel-6 | TSG |  |  |  |  |  |  |  |
| 254 | 33.6 | OSA interfaces at different levels of abstractions (Parlay X, Web services) | 305d? | 2003-07-14 A | 2004-09-10 A | 100% |  | 2003-07-14 | 2004-06-18 | 245d? |  | finish no earlier than 2004-09-10 | N5 | 2440h | 2440h |  | Rel-6 | TSG |  |  |  |  |  |  |  |
| 255 | 33.7 | Introduction of migration support mechanism | 290d? | 2002-10-31 A | 2003-12-10 A | 100% |  | 2002-10-31 | 2003-12-10 | 290d? |  | finish no earlier than 2003-12-12 | N5 | 2320h | 2320h |  | Rel-6 | TSG |  |  |  |  |  |  |  |
| 256 | 33.8 | DELETE - User Profile | 367d? | 2003-04-17 | 2004-09-10 |  |  | 2003-01-23 | 2004-06-18 | 367d? | 576d | start no earlier than 2003-04-17 | N5 | 2936h |  |  | Rel-6 | TSG |  |  |  |  |  |  |  |
| 257 | 33.9 | Framework Function for Federation | 225d? | 2003-02-03 A | 2003-12-12 A | 100% |  | 2003-02-03 | 2003-12-12 | 225d? |  | finish no earlier than 2003-12-12 | N5 | 1800h | 1800h |  | Rel-6 | TSG |  |  |  |  |  |  |  |
| 258 | 33.10 | OMA dependencies on OSA | 196d? | 2003-12-18 A | 2004-09-16 | 50% | 98d? | 2004-01-01 | 2004-09-30 | 196d? | 572d | start no earlier than 2003-12-18 | OMA | 1568h | 784h |  | Rel-6 | n/a |  |  |  |  |  |  |  |

Notes:
- 228: Text3: 22.950
- 231: Text3: 22.952
- 233: Text3: 22.951
- 234: Text3: 22.011, 22.101, 22.115, 22.129
- 235: Text3: 23.251
- 237: Text3: TS25.401, TS25.413, TS25.331, TS25.304
- 239: Text3: 23.917
- 240: Text3: 23.221
- 241: [DAB - 25.05.04] - Delayed to Sept - possibly Dec 2004 / Text3: 24,228, 29.207, 29.208
- 242: Approved at SA#14. This may require BBs from CN1, CN4, SA5 and T3 / Text3: 33.102
- 243: Contribution received S3#24, S3#25
- 245: WID approved at CN#21............
- 247: Updated according to SP-040420
- 248: CN#24: TSG Approval delayed 06/04->09/04. / Text3: 22.127, 29.198, 29.998
- 250: TSG#25: 23.127 (OSA/VHE Stage 2) to be Withdrawn form Rel-6 and Replaced by new TS 23.198 OSA-only in 12/04 / Text3: 23.127 (OSA/VHE Stage 2) to be Withdrawn form Rel-6 and Replaced by new TS 23.198 OSA-only in 12/04
- 251: CN#25: TSG Approved. Completed. / Text3: 29.198-15
- 252: Text3: 29.198, 29.998
- 253: N5#26: Split WI into TS & TR. / Text3: 29.198-14
- 254: CN#25: TSG Approved. Completed. / Text3: 29.199
- 255: Text3: 29.198, 29.998
- 256: CN#24: TSG Approval delayed 06/04->09/04. Still Pending input from SA1/2. / Text3: 29.198, 29.998
- 257: Text3: 29.198, 29.998
- 258: Updated according to SP-040420. TSG#25 At approval of PX Web services, LS on OVERLAPS with OMA provided by CN5 (NP-040283 / SP-040493) for 3GPP/OMA co-ordination.

| ID | WBS | Task | Duration | Start | Finish | Complete | Remaining | Baseline start | Baseline finish | Baseline duration | Total slack | Constraint | Resources | Work | Actual work | Text1 | Text4 | Text6 | Text7 | Text8 | Text3 | Text5 | Text2 |
| --- | --- | --- | --- | --- | --- | --- | --- | --- | --- | --- | --- | --- | --- | --- | --- | --- | --- | --- | --- | --- | --- | --- | --- |
| 259 | 39 | **Addition of frequency bands to GSM** | 621d | 2002-06-28 A | 2004-11-12 | 4% | 596.04d | 2002-06-28 | 2004-11-12 | 621d | 284d |  | GP | 15320h | 615.64h | TAPS | Torben Themsen | Rel-6 | TSG | Paolo |  |  |  |
| 260 | 39.1 | **Addition of frequency bands to GSM – Changes to core specs** | 26d | 2002-11-15 A | 2002-12-20 A | 100% |  | 2002-11-15 | 2002-12-20 | 26d |  |  | G1 | 416h | 416h | TAPS-Specs | Torben Themsen | Rel-6 | TSG |  |  |  |  |
| 261 | 39.1.1 | Changes to core specs | 26d | 2002-11-15 A | 2002-12-20 A | 100% |  | 2002-11-15 | 2002-12-20 | 26d |  | finish no earlier than 2002-12-20 | G1 | 208h | 208h |  |  | Rel-6 |  |  |  |  |  |
| 262 | 39.2 | **Addition of frequency bands to GSM – Changes for conformance tests** | 621d | 2002-06-28 | 2004-11-12 |  |  | 2002-06-28 | 2004-11-12 | 621d | 284d |  | G4 | 9936h |  | TAPS-Conf | Torben Themsen | Rel-6 |  |  |  |  |  |
| 263 | 39.2.1 | 51.010-1 Add testing | 621d | 2002-06-28 | 2004-11-12 |  |  | 2002-06-28 | 2004-11-12 | 621d | 531d | finish no earlier than 2004-11-12 | G4 | 4968h |  |  |  | Rel-6 |  |  |  |  |  |
| 264 | 40 | **Seamless support of streaming services in A/Gb mode** | 1065d? | 2000-01-03 A | 2004-01-30 | 94% | 68.97d? | 2000-01-03 | 2004-01-30 | 1065d? | 489d |  | GP | 40840h | 37411.7h | SSStrea | José Luis Carrizo Martínez, Vodafone | Rel-6 | TSG | Paolo |  |  |  |
| 265 | 40.1 | **Identification of requirements for streaming** | 46d? | 2003-06-27 A | 2003-08-29 A | 100% |  | 2003-06-27 | 2003-08-29 | 46d? |  |  | G1 | 736h | 736h |  |  | Rel-6 |  |  |  |  |  |
| 266 | 35.1.1 | Requirements | 46d? | 2003-06-27 A | 2003-08-29 A | 100% |  | 2003-06-27 | 2003-08-29 | 46d? |  | finish no earlier than 2003-08-29 | G1 | 368h | 368h |  |  | Rel-6 |  |  |  |  |  |
| 267 | 40.2 | **Performance study of cell change mechanisms** | 955d? | 2000-01-03 A | 2003-08-29 A | 100% |  | 2000-01-03 | 2003-08-29 | 955d? |  |  | G1 | 30560h | 30560h |  |  | Rel-6 |  |  |  |  |  |
| 268 | 35.2.1 | Performance of NACC | 955d? | 2000-01-03 A | 2003-08-29 A | 100% |  | 2000-01-03 | 2003-08-29 | 955d? |  | finish no earlier than 2003-08-29 | G1 | 7640h | 7640h |  |  | Rel-6 |  |  |  |  |  |
| 269 | 35.2.2 | Performance of cell change in DTM for the PS domain | 955d? | 2000-01-03 A | 2003-08-29 A | 100% |  | 2000-01-03 | 2003-08-29 | 955d? |  | finish no earlier than 2003-08-29 | G1 | 7640h | 7640h |  |  | Rel-6 |  |  |  |  |  |
| 270 | 35.2.3 | Handover | 955d? | 2000-01-03 A | 2003-08-29 A | 100% |  | 2000-01-03 | 2003-08-29 | 955d? |  | finish no earlier than 2003-08-29 | G1 | 7640h | 7640h |  |  | Rel-6 |  |  |  |  |  |
| 271 | 40.3 | **Reduction of service interruption times and packet loss during mobility procedures** | 106d? | 2003-06-27 A | 2003-11-21 | 99% | 0d? | 2003-06-27 | 2003-11-21 | 106d? | 0d |  | G2 | 4240h | 3396h |  |  | Rel-6 |  |  |  |  |  |
| 272 | 35.3.1 | Optimisations of existing mechanisms/procedures | 106d? | 2003-06-27 A | 2003-11-21 A | 100% |  | 2003-06-27 | 2003-11-21 | 106d? |  | finish no earlier than 2003-11-21 | G2 | 848h | 848h |  |  | Rel-6 |  |  |  |  |  |
| 273 | 35.3.2 | Inter-system NACC | 106d? | 2003-06-27 A | 2003-11-21 A | 100% |  | 2003-06-27 | 2003-11-21 | 106d? |  | finish no earlier than 2003-11-21 | G2 | 848h | 848h |  |  | Rel-6 |  |  |  |  |  |
| 274 | 35.3.3 | PS Handover (within GERAN and between GERAN and UTRAN) | 106d? | 2003-06-27 A | 2003-11-21 A | 100% |  | 2003-06-27 | 2003-11-21 | 106d? |  | finish no earlier than 2003-11-21 | G2 | 848h | 848h |  |  | Rel-6 |  |  |  |  |  |
| 275 | 35.3.4 | Dependency to other features | 106d? | 2003-06-27 A | 2003-11-21 A | 100% |  | 2003-06-27 | 2003-11-21 | 106d? |  | finish no earlier than 2003-11-21 | G2 | 848h | 848h |  |  | Rel-6 |  |  |  |  |  |
| 276 | 40.5 | **MS conformance testing** | 31d? | 2003-12-19 A | 2004-01-30 A | 100% |  | 2003-12-19 | 2004-01-30 | 31d? |  |  | G3 | 248h | 248h |  |  | Rel-6 |  |  |  |  |  |
| 277 | 35.4.1 | MS conformance tests | 31d? | 2003-12-19 A | 2004-01-30 A | 100% |  | 2003-12-19 | 2004-01-30 | 31d? |  | finish no earlier than 2004-01-30 | G4,G5 | 248h | 248h |  |  | Rel-6 |  |  |  |  |  |
| 278 | 35.5 | GERAN A/Gb mode security enhancements | 261d? | 2002-09-26 A | 2003-09-25 | 10% | 234.9d? | 2002-09-26 | 2003-09-25 | 261d? | 827d | finish no earlier than 2003-09-25 | S3 | 2088h | 208.8h |  | Peter Howard, Vodafone | Rel-6 |  |  | 33.102 | peter.howard@vodafone.com |  |
| 279 | 41 | Performance characterisation of default codecs for PS conversational multimedia application | 455d | 2002-09-13 A | 2004-06-10 A | 100% |  | 2002-09-13 | 2004-06-10 | 455d |  | finish no earlier than 2004-06-10 | S4 | 3640h | 3640h | CODCAR | Pasi Ojala (Nokia) | Rel-6 | TSG | Paolo | TR 26.935 | pasi.s.ojala@nokia.com |  |
| 280 | 43 | Study on Privacy Capability | 83d | 2003-11-10 A | 2004-03-03 | 85% | 12.45d | 2003-11-10 | 2004-03-03 | 83d | 713d | start no earlier than 2003-11-10 | S1 | 664h | 564.4h | PrivCap | Liz Daniel, Lucent | Rel-6 | TSG | Michael | TR 21.xyz |  |  |
| 281 | 44 | **OAM&P** | 715d? | 2002-09-12 A | 2005-06-08 | 84% | 116.28d? | 2002-09-12 | 2004-12-08 | 585d? | 136d |  | S5 | 34083.5h | 23810.6h | OAM | Michael TRUSS (Motorola) | Rel-6 | TSG | Adrian | 32-series | Michael.Truss@MOTOROLA.COM |  |
| 282 | 44.1 | Principles, high level Requirements and Architecture | 526d | 2002-09-12 A | 2004-09-16 A | 100% |  | 2002-09-12 | 2004-09-16 | 526d |  | finish no earlier than 2004-09-16 | S5 | 4208h | 4208h | OAM-AR | Michael TRUSS (Motorola) | Rel-6 | TSG |  | 32.101, 32.102 | Michael.Truss@MOTOROLA.COM | BCaM |
| 283 | 44.2 | Performance Management | 591d | 2002-09-12 A | 2004-12-16 | 95% | 29.55d | 2002-09-12 | 2004-09-16 | 526d | 507d | finish no earlier than 2004-12-16 | S5 | 4728h | 4491.6h | OAM-PM | Christian TOCHE (Nortel Networks) | Rel-6 | TSG |  | 32.401/3, 52.402, 32.411/2/3, 32.432/5/6 | toche@NORTELNETWORKS.COM | BCaM |
| 284 | 44.4 | Network Infrastructure Management | 591d | 2002-09-12 A | 2004-12-16 | 95% | 29.55d | 2002-09-12 | 2004-09-16 | 526d | 507d | finish no earlier than 2004-12-16 | S5 | 4728h | 4491.6h | OAM-NIM | Thomas TOVINGER (Ericsson) | Rel-6 | TSG |  | 32.15x, 32.3/6/7xy | Thomas.Tovinger@emw.ericsson.se |  |

Notes:
- 260: Ready
- 262: Not started
- 265: Started
- 267: Started
- 271: Completed at GERAN#17
- 276: Closed, no work needed
- 277: Closed, no work needed
- 278: Possible changes to 33.102 or new specification needed.
- 281: SA#24: Completionl delayed 09/04->12/04 due to OAM-Trace.
- 282: SA#24: Completed
- 283: TSG#25: for Info 32.432/5/6 => Approval 12/04. Withdrawn from Rel-6 32.431/3/4.

| ID | WBS | Task | Duration | Start | Finish | Complete | Remaining | Baseline start | Baseline finish | Baseline duration | Total slack | Constraint | Resources | Work | Actual work | Text1 | Text3 | Text4 | Text5 | Text7 | Text8 | Text6 | Text2 | Text9 |
| --- | --- | --- | --- | --- | --- | --- | --- | --- | --- | --- | --- | --- | --- | --- | --- | --- | --- | --- | --- | --- | --- | --- | --- | --- |
| 285 | 44.5 | **Trace Management** | 709d? | 2002-09-20 A | 2005-06-08 | 67% | 231.98d? | 2002-09-20 | 2004-12-08 | 579d? | 136d |  | S5 | 14821.9h | 7547.05h | OAM-Trace | 32.42x, 52.008 | Kari RÖNKÄ (Nokia) | kari.t.ronka@nokia.com | TSG |  |  |  |  |
| 286 | 38.4.1 | Subscriber and UE trace management | 585d | 2002-09-20 A | 2004-12-16 | 95% | 29.25d | 2002-09-20 | 2004-09-16 | 520d | 507d | finish no earlier than 2004-12-16 | S5 | 4680h | 4446h | OAM-Trace | 32.421/2/3, 52.008 | Kari RÖNKÄ (Nokia) | kari.t.ronka@nokia.com | TSG |  |  |  |  |
| 287 | 38.4.2 | Subscriber and equipment trace in UTRAN | 268d? | 2003-06-06 A | 2004-06-15 A | 100% |  | 2003-06-06 | 2004-06-15 | 268d? |  | finish no earlier than 2004-06-15 | R3 | 2144h | 2144h | OAM-Trace-RAN | TS25.413, 25.420, 25.423 | Yann Sehedi, Nortel | sehedic@nortelnetworks.com | TSG | MCC_RAN |  |  |  |
| 288 | 38.4.3 | SIP enhancements for trace | 343d? | 2004-02-16 A | 2005-06-08 | 2% | 336.14d? | 2004-02-16 | 2004-12-08 | 213d? | 383d | finish no earlier than 2005-06-08 | N1 | 2744h | 54.88h |  |  |  |  |  |  |  |  |  |
| 289 | 38.4.4 | Trace Management, Stage3 | 132.74d? | 2004-06-09 A | 2004-12-16 | 48% | 69.37d? | 2004-02-16 | 2004-12-08 | 213d? | 507d | finish no earlier than 2004-12-16 | N4 | 1061.93h | 506.97h | OAM-Trace | TS 23.205, 29.232, 29.060, 29.002, 29.228 | Seppo Kauntola ( Nokia Corporation) | seppo.kauntola@nokia.com |  |  |  |  |  |
| 290 | 39 | **Charging Management** | 541d? | 2002-11-21 A | 2004-12-16 | 86% | 75.57d? | 2002-11-21 | 2004-09-16 | 476d? | 260d |  | S5 | 24832h | 17548.2h | CH | 32.2xy | Karl-Heinz NENNER (T-Mobile) | karl-heinz.nenner@t-mobile.de | TSG | Adrian | Rel-6 |  |  |
| 291 | 39.1 | Charging Management for Bearer level | 455d? | 2003-03-21 A | 2004-12-16 | 90% | 45.5d? | 2003-03-21 | 2004-09-16 | 390d? | 507d | finish no earlier than 2004-12-16 | S5 | 3640h | 3276h | CH-BC |  | Benni ALEXANDER (Nokia) |  | TSG |  | Rel-6 |  |  |
| 292 | 39.2 | Charging Management for the IMS | 455d? | 2003-03-21 A | 2004-12-16 | 90% | 45.5d? | 2003-03-21 | 2004-09-16 | 390d? | 507d | finish no earlier than 2004-12-16 | S5 | 3640h | 3276h | CH-IC |  | Patrik TEPPO (Ericsson) |  | TSG |  | Rel-6 |  |  |
| 293 | 39.3 | Charging Management for the Service domain | 455d? | 2003-03-21 A | 2004-12-16 | 90% | 45.5d? | 2003-03-21 | 2004-09-16 | 390d? | 507d | finish no earlier than 2004-12-16 | S5 | 3640h | 3276h | CH-SC |  | Gerald GÖRMER (Siemens) |  | TSG |  | Rel-6 |  |  |
| 294 | 39.4 | **Overall architectural aspects of IP flow based bearer level charging** | 535d? | 2002-11-21 A | 2004-12-08 | 78% | 118.46d? | 2002-11-21 | 2004-07-30 | 442d? | 266d |  | S2 | 9584h | 6106.88h | CH-FBC | 23.125 |  |  |  |  | Rel-6 |  |  |
| 295 | 39.4.1 | Overall definition of FBC architecture | 334d? | 2002-11-21 A | 2004-03-02 | 99% | 1d? | 2002-11-21 | 2004-03-02 | 334d? | 714d | start no earlier than 2002-11-21 | S2 | 2672h | 2664h |  |  |  |  |  |  | Rel-6 |  |  |
| 296 | 39.4.2 | Study on providing policy control with FBC | 130d? | 2004-02-02 A | 2004-07-30 | 95% | 6.5d? | 2004-02-02 | 2004-07-30 | 130d? | 359d | start no earlier than 2004-02-01 | S2 | 1040h | 988h |  |  |  |  |  |  | Rel-6 |  |  |
| 297 | 39.4.3 | Gx interface for flow based charging | 99.5d? | 2004-02-02 A | 2004-12-08 | 50% | 49.75d? | 2004-02-02 | 2004-07-30 | 130d? | 266d | finish no earlier than 2004-12-08 | N3 | 796h | 398h |  | 29.210 |  |  |  |  | Rel-6 |  |  |
| 298 | 39.4.4 | Rx interface for flow based charging | 99.5d? | 2004-02-02 A | 2004-12-08 | 10% | 89.55d? | 2004-02-02 | 2004-07-30 | 130d? | 266d | finish no earlier than 2004-12-08 | N3 | 796h | 79.6h |  | 29.209 | Javier Gonzalez Gallego | ggfj@nortelnetworks.com |  |  | Rel-6 |  |  |
| 299 | 13 | **Rel-6 UICC/USIM enhancements and interworking** | 1164d | 2000-09-25 A | 2005-03-10 | 78% | 255.31d | 2000-09-25 | 2004-02-19 | 889d | 200d |  | T3 | 35312h | 25258.6h | USAT1 |  |  |  | TSG | Claus | Rel-6 | Ter | 1800 |
| 300 | 13.1 | **UICC API** | 777d | 2002-03-20 A | 2005-03-10 | 64% | 283d | 2002-03-20 | 2004-02-19 | 502d | 200d |  | T3 | 14936h | 9496.01h | USAT1-API |  |  |  |  |  | Rel-6 | Ter | 1802 |
| 301 | 13.1.1 | Java API Test specification | 59d | 2002-03-20 A | 2002-06-10 A | 100% |  | 2002-03-20 | 2002-06-10 | 59d |  | finish no earlier than 2002-09-20 | T3 | 472h | 472h |  |  | Mario Pérez (Microelectrónica Española) |  |  |  | Rel-6 |  |  |
| 302 | 13.1.2 | Java API Test specification (TS 43.019 Rel-5) | 268d | 2002-05-30 A | 2003-06-09 A | 100% |  | 2002-05-30 | 2003-06-09 | 268d |  | finish no earlier than 2003-09-17 | T3 | 2144h | 2144h |  |  | Mario Pérez (Microelectrónica Española) |  |  |  | Rel-6 |  |  |
| 303 | 40.1.3 | 2G/3G Java Card™ API based applet interworking | 244d | 2003-03-17 A | 2004-02-19 A | 100% |  | 2003-03-17 | 2004-02-19 | 244d |  | finish no earlier than 2004-02-19 | T3 | 1952h | 1952h | USAT1-API |  | Stéphane Andrau-Oberthur Card Systems |  | TSG |  | Rel-6 |  |  |
| 304 | 40.1.4 | (U)SIM API for Java Card Testing Work Item | 519d | 2003-03-17 A | 2005-03-10 | 24% | 397d | 2003-03-17 | 2004-02-19 | 244d | 200d | finish no earlier than 2005-03-10 | T3 | 4152h | 976h |  | 31.213 | Christophe Begassat (Axalto) | 'cbegassat@axalto.com' | TSG | Friedhelm | Rel-6 |  |  |
| 305 | 40.2 | **Rel-6 USIM toolkit enhancements** | 525d | 2000-09-25 A | 2002-09-27 | 99% | 0d | 2000-09-25 | 2002-09-27 | 525d | 0d |  | T3 | 14160h | 10910h |  |  |  |  |  | Claus | Rel-6 |  |  |
| 306 | 40.2.1 | **C SIM API** | 525d | 2000-09-25 A | 2002-09-27 A | 100% |  | 2000-09-25 | 2002-09-27 | 525d |  |  | T3 | 9960h | 9960h | USAT1-API-MULTOS |  |  |  | TSG |  | Rel-6 | Ter | 2031 |
| 307 | 40.2.1.1 | Specification | 525d | 2000-09-25 A | 2002-09-27 A | 100% |  | 2000-09-25 | 2002-09-27 | 525d |  | finish no earlier than 2002-09-27 | T3 | 4200h | 4200h |  |  | Neil Livingston – Aspects Software |  | TSG |  | Rel-6 | Ter | 2032 |
| 308 | 40.2.1.2 | Test specification | 195d | 2001-01-01 A | 2001-09-28 A | 100% |  | 2001-01-01 | 2001-09-28 | 195d |  | finish no earlier than 2001-09-28 | T3 | 1560h | 1560h |  |  | Neil Livingston – Aspects Software |  | TSG |  | Rel-6 | Ter | 2033 |

Notes:
- 285: TSG#25: SA5 completion 12/04 depending on CN1/CN4 input. CN1 cannot complete 24.229 trace without IETF dependency => estimate 05/05.
- 286: TSG#25: for Info 32.423/52.008, for Approval 32.422.
- 290: TSG#25 For Approval 32.240/51/7095/99. For Info 32.296. Approval 12/04 32.260/71/96/98. Date uncertain WLAN/PoC Charging 32.252/72 (Reason: SA2/OMA dependencies).
- 300: 8/3/2001: test spec is based on R99 core spec, so deleted from Workplan

| ID | WBS | Task | Duration | Start | Finish | Complete | Remaining | Baseline start | Baseline finish | Baseline duration | Total slack | Constraint | Resources | Work | Actual work | Text1 | Text4 | Text5 | Text6 | Text7 | Text8 | Text3 |
| --- | --- | --- | --- | --- | --- | --- | --- | --- | --- | --- | --- | --- | --- | --- | --- | --- | --- | --- | --- | --- | --- | --- |
| 309 | 41 | **Packet Switched Streaming Services Rel-6** | 544d? | 2002-11-18 A | 2004-12-16 | 91% | 46.74d? | 2002-11-18 | 2004-09-16 | 479d? | 260d |  | S4 | 9240h | 8446.06h | PSSrel6 | Olle Franceschi (Ericsson) | olle.franceschi@ericsson.com | Rel-6 | TSG | Paolo |  |
| 310 | 41.1 | Stage 1 | 86d? | 2002-11-18 A | 2003-03-17 A | 100% |  | 2002-11-18 | 2003-03-17 | 86d? |  | finish no earlier than 2003-03-17 | S1 | 688h | 688h |  |  |  | Rel-6 | TSG |  | 22.233 |
| 311 | 41.2 | Stage 3 | 525d? | 2002-12-13 A | 2004-12-16 | 90% | 52.5d? | 2002-12-13 | 2004-09-16 | 460d? | 260d | finish no earlier than 2004-12-16 | S4 | 4200h | 3780h | PSSrel6-Stage3 | Olle Franceschi (Ericsson) | olle.franceschi@ericsson.com | Rel-6 | WG | Paolo | 26.233, 26.234, 26.244, 26.245, 26.246 |
| 312 | 42 | AMR-WB extension for high audio quality | 525d | 2002-12-13 A | 2004-12-16 | 95% | 26.25d | 2002-12-13 | 2004-06-10 | 390d | 260d | finish no earlier than 2004-12-16 | S4 | 4200h | 3990h | AMRWB+ | Janne Vainio (Nokia) | janne.m.vainio@nokia.com | Rel-6 | TSG | Paolo |  |
| 313 | 43 | Codec Enhancements for Packet Switched Conversational Multimedia Applications | 198d? | 2004-03-16 A | 2004-12-16 | 80% | 39.6d? | 2004-03-16 | 2004-09-16 | 133d? | 260d | finish no earlier than 2004-12-16 | S4 | 1584h | 1267.2h | CEPSCM | Miska Hannuksela (Nokia) | miska.hannuksela@nokia.com | Rel-6 | WG | Paolo | 26.235, 26.236 |
| 314 | 44 | 3G-324M Improvements | 198d? | 2004-03-16 A | 2004-12-16 | 80% | 39.6d? | 2004-03-16 | 2004-09-16 | 133d? | 260d | finish no earlier than 2004-12-16 | S4 | 1584h | 1267.2h | 3G-324MI | Bo Burman, Ericsson | bo.burman@ericsson.com | Rel-6 | WG | Paolo | 26.111, 26.911 |
| 315 | 45 | Single Antenna Receiver Interference Cancellation (SAIC) | 420.92d? | 2002-11-15 A | 2004-08-27 | 90% | 42.09d? | 2002-11-15 | 2004-06-25 | 375.92d? | 339d | finish no earlier than 2004-08-27 | GP; G1 | 6734.72h | 6061.25h | SAIC | Marc Grant, Cingular Wireless |  | Rel-6 | TSG | Paolo |  |
| 316 | 46 | **Support of Conversational Services in A/Gb mode via the PS domain** | 406d? | 2003-02-07 A | 2004-08-27 | 28% | 292.78d? | 2003-02-07 | 2004-08-27 | 406d? | 339d |  | GP | 13512h | 2258.93h | SCSAGB | David Bladsjö, Ericsson | david.bladsjo@ericsson.com | Rel-6 | TSG | Paolo |  |
| 317 | 46.1 | Creation of a TR | 206d? | 2003-02-07 A | 2003-11-21 A | 100% |  | 2003-02-07 | 2003-11-21 | 206d? |  | finish no earlier than 2003-11-21 | GP | 1648h | 1648h | SCSAGB-TR | David Bladsjö, Ericsson |  | Rel-6 | TSG |  |  |
| 318 | 46.2 | Stage 2 | 201d? | 2003-11-21 A | 2004-08-27 | 35% | 130.65d? | 2003-11-21 | 2004-08-27 | 201d? | 339d | finish no earlier than 2004-08-27 | GP | 1608h | 562.8h | SCSAGB-Stage2 | David Bladsjö, Ericsson |  | Rel-6 | TSG |  |  |
| 319 | 46.3 | Radio Channel Support | 146d? | 2004-02-06 | 2004-08-27 |  |  | 2004-02-06 | 2004-08-27 | 146d? | 339d | finish no earlier than 2004-08-27 | GP | 1168h |  | SCSAGB-RCS | David Bladsjö, Ericsson |  | Rel-6 | TSG |  |  |
| 320 | 46.4 | Definition of radio resource management functionality | 146d? | 2004-02-06 | 2004-08-27 |  |  | 2004-02-06 | 2004-08-27 | 146d? | 339d | finish no earlier than 2004-08-27 | GP; G2 | 2336h |  | SCSAGB-RRM | David Bladsjö, Ericsson |  | Rel-6 | TSG |  |  |
| 321 | 46.5 | PS Handover | 146d? | 2004-02-06 | 2004-08-27 |  |  | 2004-02-06 | 2004-08-27 | 146d? | 339d | finish no earlier than 2004-08-27 | GP | 1168h |  | SCSAGB-PSH | David Bladsjö, Ericsson |  | Rel-6 | TSG |  |  |
| 322 | 46.6 | Modifications to FLO | 146d? | 2004-02-06 | 2004-08-27 |  |  | 2004-02-06 | 2004-08-27 | 146d? | 339d | finish no earlier than 2004-08-27 | GP; G2 | 2336h |  | SCSAGB-FLO | David Bladsjö, Ericsson |  | Rel-6 | TSG |  |  |
| 323 | 47 | **Enhancement of dialled service for CAMEL** | 199d | 2003-03-28 A | 2003-12-31 A | 100% |  | 2003-03-28 | 2003-12-31 | 199d |  |  | S1 | 3184h | 3184h | EDCAMEL | Craig Bishop, Samsung Electronics Research Institute |  | Rel-6 | TSG | Andrijana |  |
| 324 | 47.1 | Stages 2 and 3 | 199d | 2003-03-28 A | 2003-12-31 A | 100% |  | 2003-03-28 | 2003-12-31 | 199d |  | finish no earlier than 2003-09-19 | N4 | 1592h | 1592h |  |  |  | Rel-6 |  |  |  |
| 325 | 48 | Bandwidth and resource savings in CS networks | 273d? | 2003-06-01 A | 2004-06-16 A | 100% |  | 2003-06-01 | 2004-06-16 | 273d? |  | finish no earlier than 2004-06-16 | S2 | 2184h | 2184h | BARS |  |  | Rel-6 |  | Sang-Ui | 23.977 |
| 326 | 49 | FS on (U)SIM Security Reuse by Peripheral Devices on Local Interfaces | 127d? | 2003-07-03 A | 2003-12-26 | 5% | 120.65d? | 2003-07-03 | 2003-12-26 | 127d? | 514d | finish no earlier than 2003-12-26 | S3 | 1016h | 50.8h |  | Raziq Yaqub, Toshiba America Research Inc. | ryaqub@tari.toshiba.com | Rel-6 | TSG | Maurice |  |
| 327 | 50 | **Multiple TBF in A/Gb mode** | 581d? | 2002-04-05 A | 2004-06-25 | 65% | 201.05d? | 2002-04-05 | 2004-06-25 | 581d? | 384d |  | GP; G2 | 37368h | 27408.6h | MULTBF | Gunnar Mildh, Ericsson |  | Rel-6 | TSG | Paolo |  |
| 328 | 50.1 | **Multiple TBF in A/Gb mode** | 366d? | 2002-04-05 A | 2003-08-29 A | 100% |  | 2002-04-05 | 2003-08-29 | 366d? |  |  | GP; G2 | 23424h | 23424h | MULTBF-Agbmode | Gunnar Mildh, Ericsson |  | Rel-6 | TSG |  |  |
| 329 | 50.1.1 | Multiple TBF Concept paper | 366d? | 2002-04-05 A | 2003-08-29 A | 100% |  | 2002-04-05 | 2003-08-29 | 366d? |  | finish no earlier than 2003-08-29 | GP; G2 | 5856h | 5856h |  |  |  | Rel-6 |  |  |  |
| 330 | 50.1.2 | Multiple TBF Stage 2 (43.064) CRs | 366d? | 2002-04-05 A | 2003-08-29 A | 100% |  | 2002-04-05 | 2003-08-29 | 366d? |  | finish no earlier than 2003-08-29 | GP; G2 | 5856h | 5856h |  |  |  | Rel-6 |  |  |  |
| 331 | 50.1.3 | Multiple TBF Stage 3 (44.060) CRs | 366d? | 2002-04-05 A | 2003-08-29 A | 100% |  | 2002-04-05 | 2003-08-29 | 366d? |  | finish no earlier than 2003-08-29 | GP; G2 | 5856h | 5856h |  |  |  | Rel-6 |  |  |  |
| 332 | 50.2 | Multiple TBF in A/Gb mode – MS testing | 581d? | 2002-04-05 | 2004-06-25 |  |  | 2002-04-05 | 2004-06-25 | 581d? | 384d | finish no earlier than 2004-06-25 | G3 | 4648h |  | MULTBF-Testing | Gunnar Mildh, Ericsson |  | Rel-6 | TSG | Paolo |  |

Notes:
- 310: 2nd resp SA4
- 311: Completed except SVG Tiny 1.2
- 318: Started
- 319: Not started
- 320: Not started
- 321: Not started
- 322: Not started
- 326: Approved TSG#20
- 331: Not started
- 332: Not started

| ID | WBS | Task | Duration | Start | Finish | Complete | Remaining | Baseline start | Baseline finish | Baseline duration | Total slack | Constraint | Resources | Work | Actual work | Text1 | Text4 | Text6 | Text7 | Text8 | Text5 | Text3 |
| --- | --- | --- | --- | --- | --- | --- | --- | --- | --- | --- | --- | --- | --- | --- | --- | --- | --- | --- | --- | --- | --- | --- |
| 333 | 51 | **Alignment between the test-regimes for GERAN capable MS** | 261d? | 2003-08-29 A | 2004-08-27 | 80% | 52.2d? | 2003-08-29 | 2004-08-27 | 261d? | 339d |  | G3 | 4176h | 1670.4h | ALTERE | Toubassi, Ericsson | Rel-6 | TSG | Michael |  |  |
| 334 | 51.1 | Determine the controversial test cases in the different test regimes and align them with 3GPP GERAN test specifications. Such test cases to be added to TS 51.010. | 261d? | 2003-08-29 A | 2004-08-27 | 80% | 52.2d? | 2003-08-29 | 2004-08-27 | 261d? | 339d | finish no earlier than 2004-08-27 | G3 | 2088h | 1670.4h | ALTERE-TC |  | Rel-6 | TSG |  |  |  |
| 335 | 52 | Addition of U-TDOA in the CS domain | 111d? | 2003-11-21 A | 2004-04-23 A | 100% |  | 2003-11-21 | 2004-04-23 | 111d? |  | finish no earlier than 2004-04-23 | GP | 888h | 888h | UTDOACS | Bob Gross, Rhys Robinson, TruePosition, Inc. | Rel-6 | TSG | Paolo | rlgross@trueposition.com |  |
| 336 | 53 | Addition of U-TDOA in the PS domain | 361d? | 2003-06-27 A | 2004-11-12 | 5% | 342.95d? | 2003-06-27 | 2004-11-12 | 361d? | 284d | finish no earlier than 2004-11-12 | GP | 2888h | 144.4h | UTDOAPS | Bob Gross, Rhys Robinson, TruePosition, Inc. | Rel-6 | TSG | Paolo | rlgross@trueposition.com |  |
| 337 | 54 | **Downlink Advanced Receiver Performance** | 332d? | 2003-11-21 A | 2005-02-28 | 27% | 243.94d? | 2003-11-21 | 2005-02-28 | 332d? | 208d |  | GP | 16576h | 2872.53h | DARP | Tommy Bysted, Nokia | Rel-6 | TSG | Paolo | tommy.bysted@nokia.com |  |
| 338 | 54.1 | DARP test scenarios | 201d? | 2003-11-21 A | 2004-08-27 | 45% | 110.55d? | 2003-11-21 | 2004-08-27 | 201d? | 339d | finish no earlier than 2004-08-27 | GP | 1608h | 723.6h | DARP-TS | Tommy Bysted, Nokia | Rel-6 | TSG | Paolo | tommy.bysted@nokia.com |  |
| 339 | 54.2 | **DARP for GMSK modulated voice services** | 201d? | 2004-02-06 A | 2004-11-12 | 15% | 170.85d? | 2004-02-06 | 2004-11-12 | 201d? | 284d |  | GP | 4824h | 482.4h | DARP-GMSK | Tommy Bysted, Nokia | Rel-6 | TSG | Paolo | tommy.bysted@nokia.com |  |
| 340 | 54.2.1 | Performance requirements in 45.005 | 201d? | 2004-02-06 A | 2004-11-12 | 15% | 170.85d? | 2004-02-06 | 2004-11-12 | 201d? | 284d | finish no earlier than 2004-11-12 | GP | 1608h | 241.2h | DARP-GMSK-Perf |  | Rel-6 | TSG |  |  |  |
| 341 | 54.2.2 | Radio subsystem link control in 45.008 | 201d? | 2004-02-06 A | 2004-11-12 | 15% | 170.85d? | 2004-02-06 | 2004-11-12 | 201d? | 284d | finish no earlier than 2004-11-12 | GP | 1608h | 241.2h | DARP-GMSK-LC |  | Rel-6 | TSG |  |  |  |
| 342 | 54.3 | **DARP for GPRS and EGPRS MCS1-MCS4** | 201d? | 2004-02-06 A | 2004-11-12 | 10% | 180.9d? | 2004-02-06 | 2004-11-12 | 201d? | 284d |  | GP | 4824h | 321.6h | DARP-GPRSE | Tommy Bysted, Nokia | Rel-6 | TSG | Paolo | tommy.bysted@nokia.com |  |
| 343 | 54.3.1 | Performance requirements in 45.005 | 201d? | 2004-02-06 A | 2004-11-12 | 10% | 180.9d? | 2004-02-06 | 2004-11-12 | 201d? | 284d | finish no earlier than 2004-11-12 | GP | 1608h | 160.8h | DARP-GPRSE-Perf |  | Rel-6 | TSG |  |  |  |
| 344 | 54.3.2 | Radio subsystem link control in 45.008 | 201d? | 2004-02-06 A | 2004-11-12 | 10% | 180.9d? | 2004-02-06 | 2004-11-12 | 201d? | 284d | finish no earlier than 2004-11-12 | GP | 1608h | 160.8h | DARP-GPRSE-LC |  | Rel-6 | TSG |  |  |  |
| 345 | 54.4 | DARP Capability signalling | 201d? | 2003-11-21 A | 2004-08-27 | 75% | 50.25d? | 2003-11-21 | 2004-06-25 | 156d? | 339d | finish no earlier than 2004-08-27 | GP | 1608h | 1206h | DARP-CAPSIG | Tommy Bysted, Nokia | Rel-6 | TSG | Paolo | tommy.bysted@nokia.com |  |
| 346 | 54.5 | GERAN MS Conformance test for DARP | 132d? | 2004-08-27 A | 2005-02-28 | 10% | 118.8d? | 2004-08-27 | 2005-02-28 | 132d? | 208d | finish no earlier than 2005-02-28 | G3 | 1056h | 105.6h | ARP-ConfTest | Tommy Bysted, Nokia | Rel-6 | TSG | Michael | tommy.bysted@nokia.com |  |
| 347 | 55 | **Reduction of PS service interruption in Dual Transfer Mode** | 256d? | 2003-11-21 A | 2004-11-12 | 50% | 128.82d? | 2003-11-21 | 2004-11-12 | 256d? | 284d |  | G2 | 5808h | 1892.18h | PSintDTM | Toby Proctor, Siemens | Rel-6 | TSG | Gert | toby.proctor@roke.co.uk |  |
| 348 | 55.1 | Use case and requirement definition | 111d? | 2003-11-21 A | 2004-04-23 A | 100% |  | 2003-11-21 | 2004-04-23 | 111d? |  | finish no earlier than 2004-04-23 | G2 | 888h | 888h | PSintDTM-Req | Toby Proctor, Siemens | Rel-6 | TSG | Gert | toby.proctor@roke.co.uk |  |
| 349 | 55.2 | Performance Study of Current Procedures | 111d? | 2003-11-21 A | 2004-04-23 A | 100% |  | 2003-11-21 | 2004-04-23 | 111d? |  | start no earlier than 2003-11-21 | G2 | 888h | 888h | PSintDTM-Perf | Toby Proctor, Siemens | Rel-6 | TSG | Gert | toby.proctor@roke.co.uk |  |
| 350 | 55.3 | Reduction of service interruption times and packet loss during Dual Transfer Mode and mobility procedures | 46d? | 2004-04-23 A | 2004-06-25 | 25% | 34.5d? | 2004-04-23 | 2004-06-25 | 46d? | 384d | finish no earlier than 2004-06-25 | G2 | 368h | 92h | PSintDTM-Reduct | Toby Proctor, Siemens | Rel-6 | TSG | Gert | toby.proctor@roke.co.uk |  |
| 351 | 55.4 | MS Conformance testing | 101d? | 2004-06-25 | 2004-11-12 |  |  | 2004-06-25 | 2004-11-12 | 101d? | 284d | finish no earlier than 2004-11-12 | G3 | 808h |  | PSintDTM-ConfMS |  | Rel-6 | TSG | Michael |  |  |
| 352 | 55.5 | BTS Conformance testing | 101d? | 2004-06-25 | 2004-11-12 |  |  | 2004-06-25 | 2004-11-12 | 101d? | 284d | finish no earlier than 2004-11-12 | G3 | 808h |  | PSintDTM-ConfBTS |  | Rel-6 | TSG | Michael |  |  |
| 353 | 56 | CAMEL prepay interworking with SCUDIF | 206d | 2003-12-08 A | 2004-10-05 |  | 206d | 2003-12-08 | 2004-10-05 | 206d | 312.7d |  | N4 | 1648h |  | SCCAMEL |  | Rel-6 |  | Kimmo |  |  |
| 354 | 57 | **Circuit Switched Video and Voice Service Improvements** | 210d? | 2004-01-12 A | 2004-10-29 | 64% | 75.97d? | 2004-01-12 | 2004-10-29 | 210d? | 294d |  | S1 | 6896h | 3885.2h | CS_VSS | John Watson, Vodafone Group | Rel-6 | TSG | Michael |  | 23.801 |
| 355 | 57.1 | Stage 1 - Requirements | 199d | 2004-01-12 A | 2004-10-14 A | 100% |  | 2004-01-12 | 2004-10-14 | 199d |  | finish no earlier than 2004-10-14 | S1 | 1592h | 1592h |  | John Watson, Vodafone Group | Rel-6 | TSG | Michael |  |  |
| 356 | 57.2 | Stage 2 Study on architecture alternatives | 155d? | 2004-01-12 A | 2004-08-13 A | 100% |  | 2004-01-12 | 2004-08-13 | 155d? |  | finish no earlier than 2004-08-13 | S2 | 1240h | 1240h |  |  |  |  |  |  |  |
| 357 | 57.3 | Stage 2 description on Redial | 130d? | 2004-05-03 A | 2004-10-29 | 63% | 48.1d? | 2004-05-03 | 2004-10-29 | 130d? | 294d | start no earlier than 2004-05-01 | S2 | 1040h | 655.2h |  |  |  |  |  |  | 23.903 |
| 358 | 57.4 | GERAN2 Part | 199d | 2004-01-12 | 2004-10-14 |  |  | 2004-01-12 | 2004-10-14 | 199d | 305d | start no earlier than 2004-01-12 | G2 | 1592h |  |  |  | Rel-6 | TSG | Gert |  |  |
| 359 | 58 | Rel-7 Features listed below | 1d? | 2000-01-03 | 2000-01-03 |  |  |  |  |  | 1553d |  |  |  |  |  |  |  |  |  |  |  |

Notes:
- 334: Started
- 335: Completed, except for potential LMU performance specs
- 336: Started
- 338: Started
- 339: Started
- 340: Started
- 341: Started
- 342: Started
- 343: Started
- 344: Started
- 345: Started
- 346: Started
- 348: Started
- 349: Started
- 350: Started
- 351: Not started
- 352: Not started

| ID | WBS | Task | Duration | Start | Finish | Complete | Remaining | Baseline start | Baseline finish | Baseline duration | Total slack | Constraint | Resources | Work | Actual work | Text1 | Text4 | Text6 | Text7 | Text8 | Text2 | Text3 | Text9 | Text5 |
| --- | --- | --- | --- | --- | --- | --- | --- | --- | --- | --- | --- | --- | --- | --- | --- | --- | --- | --- | --- | --- | --- | --- | --- | --- |
| 360 | 59 | **PS domain and IMS impacts for supporting IMS Emergency calls** | 1255d? | 2000-08-14 A | 2005-06-03 | 36% | 807.59d? | 2000-08-14 | 2005-06-03 | 1255d? | 139d |  | S2 | 50368h | 15576.7h | EMC1 | Rainer Liebhart | Rel-7 | TSG | Sang-Ui |  |  |  |  |
| 361 | 10.1.1 | Service Requirements for IP-based emergency calls | 985d | 2000-09-18 A | 2004-06-25 A | 100% |  | 2000-09-18 | 2004-06-25 | 985d |  | finish no earlier than 2004-06-25 | S1 | 7880h | 7880h |  |  | Rel-7 |  |  | CCaR | 22.976 | 1314 |  |
| 362 | 59.2 | Stage 2 | 547d? | 2003-02-26 A | 2005-03-31 | 45% | 300.85d? | 2003-02-26 | 2004-12-15 | 471d? | 185d | finish no earlier than 2005-03-31 | S2 | 4376h | 1969.2h |  | Rainer Liebhart, Siemenws | Rel-7 | TSG |  |  | 23.228, 23.060, 23.002 |  |  |
| 363 | 10.1 | **Emergency Call Enhancements for IP& PS Based Calls – stage 3** | 1255d | 2000-08-14 A | 2005-06-03 | 8% | 1156.47d | 2000-08-14 | 2005-06-03 | 1255d | 139d |  | N1 | 28272h | 2219.53h |  | Mr Atle Monrad, Ericsson | Rel-7 |  |  | CCaR |  | 1653 | Atle.Monrad@eto.ericsson.se |
| 364 | 10.1.2 | SIP emergency calls and packet emergency calls signalling flows | 1209d | 2000-10-17 A | 2005-06-03 | 16% | 1015.56d | 2000-10-17 | 2005-06-03 | 1209d | 139d | finish no earlier than 2005-06-03 | N1 | 9672h | 1547.52h |  | Mr Atle Monrad, Ericsson | Rel-7 |  |  | CCaR | TS 24.228 | 1315 | Atle.Monrad@eto.ericsson.se |
| 365 | 10.1.5 | Stage 3 for emergency calls and packet emergency calls in general | 1255d | 2000-08-14 | 2005-06-03 |  |  | 2000-08-14 | 2005-06-03 | 1255d | 139d | finish no earlier than 2005-06-03 | N1 | 10040h |  |  | Mr Atle Monrad, Ericsson | Rel-7 |  |  | CCaR | TS 24.229 | 1646 | Atle.Monrad@eto.ericsson.se |
| 366 | 60 | **Access Class Barring and Overload Protection** | 274d? | 2004-03-15 A | 2005-03-31 | 23% | 210.9d? | 2004-03-15 | 2004-11-30 | 187d? | 185d |  | S2 | 6000h | 1381.76h | ACBOP | Chris Pudney, Vodafone | Rel-7 | TSG | Sang-Ui |  | 23.898 |  |  |
| 367 | 60.1 | TR on Stage 2 (check it at SA2) | 274d? | 2004-03-15 A | 2005-03-31 | 40% | 164.4d? | 2004-03-15 | 2004-11-30 | 187d? | 185d | finish no earlier than 2005-03-31 | S2 | 2192h | 876.8h |  |  |  | TSG |  |  |  |  |  |
| 368 | 60.2 | Extra ACBOP information in RAN | 67d? | 2004-03-15 | 2004-06-15 |  |  | 2004-03-15 | 2004-06-15 | 67d? | 392d | start no earlier than 2004-03-15 | RP | 536h |  |  |  |  | TSG |  |  | 25.331 |  |  |
| 369 | 60.3 | Extra ACBOP information in GERAN | 67d? | 2004-03-15 | 2004-06-15 |  |  | 2004-03-15 | 2004-06-15 | 67d? | 392d | start no earlier than 2004-03-15 | GP | 536h |  |  |  |  | TSG |  |  | 44.018 |  |  |
| 370 | 60.4 | Potential impact on Iu interface Overload functionality | 67d? | 2004-03-15 | 2004-06-15 |  |  | 2004-03-15 | 2004-06-15 | 67d? | 392d | start no earlier than 2004-03-15 | RP | 536h |  |  |  |  | TSG |  |  | 25.413 |  |  |
| 371 | 60.5 | Stage 3 CN aspects of ACBOP | 1d? | 2004-12-08 A | 2004-12-08 | 2% | 0.98d? |  |  |  | 266d | finish no earlier than 2004-12-08 | N1 | 8h | 0.16h |  |  |  |  |  |  |  |  |  |
| 372 | 61 | **DELETE? COVERED BY 32076? - Combining CS bearers with IMS** | 274d? | 2004-03-15 A | 2005-03-31 | 36% | 175.36d? | 2004-03-15 | 2004-11-30 | 187d? | 185d |  | S2 | 4384h | 1578.24h | CSI | Mark Watson, Nortel Networks | Rel-7 | TSG | Sang-Ui |  | 23.899 |  |  |
| 373 | 61.1 | TR on Alternative Architectures for Combining CS Bearers with IMS | 274d? | 2004-03-15 A | 2005-03-31 | 36% | 175.36d? | 2004-03-15 | 2004-11-30 | 187d? | 185d | finish no earlier than 2005-03-31 | S2 | 2192h | 789.12h |  |  |  | TSG |  |  |  |  |  |
| 374 | 62 | **USSD message delivery and transfer to USIM** | 1250d? | 2000-01-03 A | 2004-10-15 | 10% | 1120.1d? | 2004-03-18 | 2004-10-15 | 152d? | 304d |  | S1 | 2440h | 253.57h |  |  | Rel-7 | TSG | Michael |  | 22.090 |  |  |
| 375 | 62.1 | Stage 1 | 152d? | 2004-03-18 A | 2004-10-15 | 10% | 136.8d? | 2004-03-18 | 2004-10-15 | 152d? | 304d | start no earlier than 2004-03-18 | S1 | 1216h | 121.6h |  |  |  | TSG | Michael |  | 22.090 |  |  |
| 376 | 62.2 | WI on Alignment with requirements regarding USSD usage | 1d? | 2000-01-03 A | 2000-01-03 | 70% | 0.3d? |  |  |  | 1553d |  | T3 | 8h | 5.6h |  | Christophe Dubois (Axalto) |  | TSG |  |  |  |  |  |
| 377 | 63 | Generic Access to A/Gb Interface | 156d? | 2004-06-25 | 2005-01-28 |  |  |  |  |  | 229d | finish no earlier than 2005-01-28 | GP | 1248h |  | GAAG | Motorola | Rel-7 | TSG | Paolo |  |  |  |  |
| 378 | 64 | **Location Services enhancements 3** | 188d? | 2004-06-28 A | 2005-03-16 | 10% | 169.2d? | 2000-08-28 | 2004-10-29 | 1090d? | 196d |  | S2 | 4976h | 497.6h | LCS3 |  | Rel-7 |  | Sang-Ui |  | 23.271 |  |  |
| 379 | 64.1 | Toward A-GNSS concept | 188d? | 2004-06-28 A | 2005-03-16 | 10% | 169.2d? | 2004-06-28 | 2005-03-16 | 188d? | 196d | start no earlier than 2004-06-28 | S1 | 1504h | 150.4h | LCS3-AGNSS | Michel MONNERAT | Rel-7 | TSG | Michael |  |  |  | Michel.monnerat@space.alcatel.fr |
| 380 | 64.2 | **LCS for 3GPP Interworking WLAN** | 123d? | 2004-06-28 A | 2004-12-16 | 10% | 110.7d? | 2004-06-28 | 2004-12-16 | 123d? | 261d |  | S1 | 1968h | 196.8h | LCS3-IWLAN | Mike Loushine, (Telcordia) | Rel-7 | TSG | Michael |  | 22.9xx |  |  |
| 381 | 64.2.1 | Feasibility study on 3GPP system to Wireless Local Area Network (WLAN) Interworking with LCS | 123d? | 2004-06-28 A | 2004-12-16 | 10% | 110.7d? | 2004-06-28 | 2004-12-16 | 123d? | 261d | finish no earlier than 2004-12-16 | S2 | 984h | 98.4h |  |  | Rel-7 |  |  |  |  |  |  |
| 382 | 65 | **FS on applicability of GALILEO for LCS** | 518d? | 2002-07-08 A | 2004-06-30 | 54% | 236.22d? | 2002-07-08 | 2004-06-30 | 518d? | 381d |  | S2 | 9248h | 3776.48h |  |  | Rel-7 |  |  |  |  |  |  |
| 383 | 65.1 | TR on Stage 2 (No contributions received, No feedback from other groups since May) | 518d? | 2002-07-08 A | 2004-06-30 | 67% | 170.94d? | 2002-07-08 | 2004-06-30 | 518d? | 381d | finish no earlier than 2004-06-30 | S2 | 4144h | 2776.48h |  |  | Rel-7 |  |  |  |  |  |  |
| 384 | 65.2 | GERAN review of the TR | 120d? | 2003-08-25 | 2004-02-06 |  |  | 2003-08-25 | 2004-02-06 | 120d? | 484d | finish no earlier than 2004-02-06 | GP | 960h |  |  |  | Rel-7 |  |  |  |  |  |  |

Notes:
- 371: NEW - inserted on 2/9/2004

| ID | WBS | Task | Duration | Start | Finish | Complete | Remaining | Baseline start | Baseline finish | Baseline duration | Total slack | Constraint | Resources | Work | Actual work | Text1 | Text3 | Text4 | Text5 | Text6 | Text7 | Text8 |
| --- | --- | --- | --- | --- | --- | --- | --- | --- | --- | --- | --- | --- | --- | --- | --- | --- | --- | --- | --- | --- | --- | --- |
| 385 | 66 | **Enhancements of VGCS in public networks for communication of public authority officials** | 179d? | 2004-06-28 A | 2005-03-03 | 9% | 163.05d? | 2004-06-28 | 2004-12-16 | 123d? | 205d |  | S1 | 3640h | 324.43h | EGCS | 42.068, 43.068 | Joerg Swetina (Siemens AG) | joerg.swetina@SIEMENS.COM | Rel-7 | TSG | Michael |
| 386 | 66.1 | Stage 1 | 123d? | 2004-06-28 A | 2004-12-16 | 20% | 98.4d? | 2004-06-28 | 2004-12-16 | 123d? | 261d | finish no earlier than 2004-12-16 | S1 | 984h | 196.8h | EGCS | 42.068, 43.068 | Joerg Swetina (Siemens AG) | joerg.swetina@SIEMENS.COM | Rel-7 | TSG | Michael |
| 387 | 66.2 | Enhancements of VGCS in public networks for communication of public authority officials | 153d? | 2004-08-03 | 2005-03-03 |  |  |  |  |  | 205d | finish no earlier than 2005-03-03 | N1 | 1224h |  |  | 43.068, 44.068, 24.008, 29.002 | Siemens |  | Rel-7 | WG | Andrijana |
| 388 | 67 | Behaviour of Multi system UEs | 188d? | 2004-06-28 A | 2005-03-16 | 10% | 169.2d? | 2004-06-28 | 2005-03-16 | 188d? | 196d | start no earlier than 2004-06-28 | S1 | 1504h | 150.4h | BMSU | 22.xxx | D Williams (QUALCOMM) | dwilliams@qualcomm.com | Rel-7 | TSG | Michael |
| 389 | 68 | Selective Disabling of UE Capabilities | 188d? | 2004-06-28 A | 2005-03-16 | 10% | 169.2d? | 2004-06-28 | 2005-03-16 | 188d? | 196d | start no earlier than 2004-06-28 | S1 | 1504h | 150.4h | SDoUE | 22.xxx | Nigel Barnes (Motorola Ltd) | Nigel.Barnes@motorola.com | Rel-7 | TSG | Michael |
| 390 | 69 | **Feasibility Study on IMS with real time services deployment** | 384d? | 2004-06-28 | 2005-12-15 |  |  | 2004-06-28 | 2005-12-15 | 384d? | 0d |  | S1 | 9216h |  | IRTSD |  |  |  | Rel-7 | TSG | Michael |
| 391 | 69.1 | Combining CS calls and IMS sessions | 384d? | 2004-06-28 | 2005-12-15 |  |  | 2004-06-28 | 2005-12-15 | 384d? | 0d | start no earlier than 2004-06-28 | S1 | 3072h |  | IRTSD-CS_IMS | 22.abc, 23.899 |  |  | Rel-7 | TSG | Michael |
| 392 | 69.2 | IMS services using CS bearers | 384d? | 2004-06-28 | 2005-12-15 |  |  | 2004-06-28 | 2005-12-15 | 384d? | 0d | start no earlier than 2004-06-28 | S2 | 3072h |  | IRTSD-IMSCS | 23.899 | Mark Watson (Nortel Networks) |  | Rel-7 | TSG | Sang-Ui |
| 393 | 70 | All-IP Network Feasibility Study | 188d? | 2004-06-28 A | 2005-03-16 | 20% | 150.4d? | 2004-06-28 | 2005-03-16 | 188d? | 196d | start no earlier than 2004-06-28 | S1 | 1504h | 300.8h | AIPFS | 22.978 | Chris Sachno (NTT DoCoMo) | c.masyu@nttdocomo.co.jp | Rel-7 | TSG | Michael |
| 394 | 71 | Enhancement of E2E QoS | 150.4d? | 2004-06-28 A | 2005-03-16 | 25% | 112.8d? | 2004-06-28 | 2005-03-16 | 188d? | 196d | finish no earlier than 2005-03-16 | S2 | 1203.2h | 300.8h | QoS7 |  |  |  | Rel-7 | TSG | Sang-Ui |
| 395 | 72 | **IMS Phase 3** | 1158d? | 2001-01-01 A | 2005-06-08 | 33% | 771.21d? |  |  |  | 136d |  | S2 | 23712h | 5192.02h |  |  |  |  | Rel-7 |  |  |
| 396 | 16.7 | **IMS Local services** | 1158d? | 2001-01-01 A | 2005-06-08 | 99% | 14.08d? | 2001-01-01 | 2004-06-04 | 895d? | 136d |  | S2 | 11896h | 5192.02h |  | 23.228 |  |  | Rel-7 |  |  |
| 397 | 16.7.1 | Stage 2 | 325d | 2001-01-01 A | 2002-03-29 A | 100% |  | 2001-01-01 | 2002-03-29 | 325d |  | start no earlier than 2001-01-01 | S2 | 2600h | 2600h |  |  |  |  | Rel-7 |  |  |
| 398 | 72.1.2 | Stage 3 for IMS Local services | 4d? | 2005-06-03 | 2005-06-08 |  |  | 2002-12-13 | 2004-06-04 | 386d? | 136d | finish no earlier than 2005-06-08 | N1 | 32h |  |  |  | Keith Drage, Lucent | drage@lucent.com | Rel-7 |  |  |
| 399 | 72.2 | Mp (MRFC - MRFP) interface (CN4 Part) | 644d | 2002-12-13 | 2005-06-01 |  |  | 2002-12-13 | 2004-11-30 | 513d | 141d | finish no earlier than 2005-06-01 | N4 | 5152h |  | IMS-CCR-Mp |  |  |  | Rel-6 |  |  |

Notes:
- 387: WI sent to NP#25 for approval
- 399: 27/11/2002 KK: WID approved at CN#18 (NP-020601)........
